# Template version 0.9

Schedule from MS Project, 2004-01-13 to 2005-01-21.
Microsoft Corporation

## Calendars

- Standard: Mon-Fri 08:00-12:00, 13:00-17:00; Sat-Sun off. Exceptions (off unless hours are given): 2004-05-27 08:00-12:00, 13:00-17:00.

## Schedule

| ID | WBS | Task | Type | Duration | Start | Finish | Predecessors | Total slack | Free slack | Constraint |
| --- | --- | --- | --- | --- | --- | --- | --- | --- | --- | --- |
| 1 | 1 | Navision-implementatieproces |  | 14d | 2005-01-03 08:30 | 2005-01-21 08:30 |  | 0d |  | start no earlier than 2005-01-03 08:30 |
| 2 | 2 | **Preanalysefase** |  | 8d? | 2004-01-13 08:30 | 2004-01-23 08:30 |  | 251.97d |  |  |
| 3 | 2.1 | **Resumé en plan** |  | 2d? | 2004-01-13 08:30 | 2004-01-15 08:30 |  | 251.97d |  |  |
| 4 | 2.1.1 | Opportunity-instructies |  | 8h? | 2004-01-13 08:30 | 2004-01-14 08:30 |  | 251.97d | 0d |  |
| 5 | 2.1.2 | Preanalyse-instructies |  | 8h? | 2004-01-13 08:30 | 2004-01-14 08:30 |  | 251.97d | 0d |  |
| 6 | 2.1.3 | Preanalyseplan |  | 8h? | 2004-01-14 08:30 | 2004-01-15 08:30 | 5, 4 | 251.97d | 0d |  |
| 7 | 2.2 | **Gap/fit-analyse op hoog niveau** |  | 3d? | 2004-01-15 08:30 | 2004-01-20 08:30 |  | 251.97d |  |  |
| 8 | 2.2.1 | Identificatie van het hele bedrijfsproces |  | 8h? | 2004-01-15 08:30 | 2004-01-16 08:30 | 6 | 251.97d | 0d |  |
| 9 | 2.2.2 | Gap/fit-analyse op hoog niveau |  | 8h? | 2004-01-16 08:30 | 2004-01-19 08:30 | 8 | 251.97d | 0d |  |
| 10 | 2.2.3 | Oplossingen van derden overwegen |  | 8h? | 2004-01-19 08:30 | 2004-01-20 08:30 | 9, 8 | 251.97d | 0d |  |
| 11 | 2.3 | **Scoping** |  | 4d? | 2004-01-15 08:30 | 2004-01-21 08:30 |  | 251.97d |  |  |
| 12 | 2.3.1 | Bedrijfs-scopingproces |  | 8h? | 2004-01-20 08:30 | 2004-01-21 08:30 | 10, 9 | 251.97d | 0d |  |
| 13 | 2.3.2 | Voorlopige analyse van de infrastructuur |  | 8h? | 2004-01-15 08:30 | 2004-01-16 08:30 | 6 | 254.97d | 3d |  |
| 14 | 2.4 | **Projectplan & voorstel** |  | 2d? | 2004-01-21 08:30 | 2004-01-23 08:30 |  | 251.97d |  |  |
| 15 | 2.4.1 | Projecttype bepalen | milestone | 8h? | 2004-01-21 08:30 | 2004-01-22 08:30 | 13, 12 | 261d |  |  |
| 16 | 2.4.2 | Projectplanning |  | 8h? | 2004-01-21 08:30 | 2004-01-22 08:30 | 12, 13 | 251.97d | 0d |  |
| 17 | 2.4.3 | Voorstel |  | 8h? | 2004-01-22 08:30 | 2004-01-23 08:30 | 16, 12, 13 | 251.97d | 0d |  |
| 18 | 3 | Goedkeuring door klant | milestone | 8h? | 2004-01-13 08:30 | 2004-01-14 08:30 |  | 267d |  |  |
| 19 | 4 | **Analysefase** |  | 8d | 2004-01-23 08:30 | 2004-02-04 08:30 |  | 251.97d |  |  |
| 20 | 4.1 | **15 dagen - gedetailleerde analyse** |  | 8d | 2004-01-23 08:30 | 2004-02-04 08:30 | 17 | 251.97d |  |  |
| 21 | 4.1.1 | Preanalyseplan bijwerken |  | 0.5d | 2004-01-23 08:30 | 2004-01-23 13:30 | 17 | 251.97d | 0d |  |
| 22 | 4.1.2 | Sandbox-omgeving maken |  | 1d | 2004-01-23 13:30 | 2004-01-26 13:30 | 21 | 258.5d |  |  |
| 23 | 4.1.3 | Gedetailleerde analyse |  | 5d | 2004-01-23 13:30 | 2004-01-30 13:30 | 21 | 254.5d |  |  |
| 24 | 4.1.4 | Gedetailleerde gap/fit-analyse |  | 7.5d | 2004-01-23 13:30 | 2004-02-04 08:30 | 21 | 252d |  |  |
| 25 | 4.1.5 | Gedetailleerde gap/fit-scoping |  | 1d | 2004-01-23 13:30 | 2004-01-26 13:30 | 21 | 251.97d | 0d |  |

| ID | WBS | Task | Type | Duration | Start | Finish | Predecessors | Total slack | Free slack |
| --- | --- | --- | --- | --- | --- | --- | --- | --- | --- |
| 26 | 5 | **Distributiefase** |  | 21.28d? | 2004-01-13 08:30 | 2004-02-11 10:45 |  | 246.72d |  |
| 27 | 2 | **2+5+2-concept (fase één)** |  | 6.53d | 2004-01-26 13:30 | 2004-02-04 08:45 | 17, 25 | 251.97d |  |
| 28 | 2.1 | **2 dagen - voorbereiding** |  | 1.88d | 2004-01-26 13:30 | 2004-01-28 11:30 |  | 251.97d | 0d |
| 29 | 2.1.1 | Dag 1 - kennisoverdracht |  | 1d | 2004-01-26 13:30 | 2004-01-27 13:30 |  | 251.97d | 0d |
| 30 | 2.1.2 | **Dag 2 - kennismaking met de klant** |  | 0.88d | 2004-01-27 13:30 | 2004-01-28 11:30 | 29 | 251.97d | 0d |
| 31 | 2.1.2.1 | Kennismakingsbijeenkomst |  | 3h | 2004-01-27 13:30 | 2004-01-27 16:30 |  | 251.97d | 0d |
| 32 | 2.1.2.2 | Installatie van client + database (live of sandbox) |  | 2h | 2004-01-27 16:30 | 2004-01-28 09:30 | 31 | 251.97d | 0d |
| 33 | 2.1.2.3 | De vragenlijsten aftekenen |  | 1h | 2004-01-28 09:30 | 2004-01-28 10:30 | 32, 31 | 251.97d | 0d |
| 34 | 2.1.2.4 | Database - bedrijfsinstellingen |  | 1h | 2004-01-28 10:30 | 2004-01-28 11:30 | 33 | 251.97d |  |
| 35 | 2.1.2.5 | Samenvatting |  | 1h | 2004-01-28 10:30 | 2004-01-28 11:30 | 33 | 251.97d |  |
| 36 | 2.2 | **5 dagen - implementatie** |  | 4.66d | 2004-01-28 11:30 | 2004-02-04 08:45 | 28 | 251.97d |  |
| 37 | 2.2.1 | **Dag 1 - kick-off** |  | 1d | 2004-01-28 11:30 | 2004-01-29 11:30 | 30 | 251.97d | 0d |
| 38 | 2.2.1.1 | Kick off-vergadering |  | 1h | 2004-01-28 11:30 | 2004-01-28 13:30 |  | 252.84d |  |
| 39 | 2.2.1.2 | Gebruikers instellen |  | 2h | 2004-01-28 11:30 | 2004-01-28 14:30 |  | 251.97d | 0d |
| 40 | 2.2.1.3 | Stamgegevensmigratie |  | 1h | 2004-01-28 14:30 | 2004-01-28 15:30 | 39 | 251.97d | 0d |
| 41 | 5.1.2.1.4 | Stamgegevenssjablonen |  | 1h | 2004-01-28 15:30 | 2004-01-28 16:30 | 40 | 251.97d | 0d |
| 42 | 2.2.1.4 | Deadlines en verantwoordelijkheid voor invoer van stamgegevens bepalen |  | 0.5h | 2004-01-28 16:30 | 2004-01-28 17:00 | 41 | 251.97d | 0d |
| 43 | 2.2.1.5 | Uiterlijk van afdrukken |  | 1h | 2004-01-29 08:00 | 2004-01-29 09:00 | 42 | 251.97d | 0d |
| 44 | 2.2.1.6 | Planning van gebruikersprocestraining (situatie vooraf voor de volgende dagen) |  | 2h | 2004-01-29 09:00 | 2004-01-29 11:00 | 43 | 251.97d | 0d |
| 45 | 2.2.1.7 | Voorbereiding dag 2 |  | 0.5h | 2004-01-29 11:00 | 2004-01-29 11:30 | 44 | 251.97d |  |
| 46 | 2.2.2 | **Dag 2 - grootboek** |  | 0.94d | 2004-01-29 11:30 | 2004-01-30 11:00 | 37 | 251.97d | 0d |
| 47 | 2.2.2.1 | Procestraining Basis Financieel | milestone | 0h | 2004-01-29 11:30 | 2004-01-29 11:30 |  | 252.91d |  |
| 48 | 2.2.2.2 | Algemene inleiding over het rekeningschema en het maken van bedrijfsboekingsgroepen. |  | 1h | 2004-01-29 11:30 | 2004-01-29 13:30 |  | 251.97d | 0d |
| 49 | 5.1.2.2.3 | De stamgegevenssjabloon valideren |  | 1h | 2004-01-29 13:30 | 2004-01-29 14:30 | 48 | 252.06d | 0d |
| 50 | 2.2.2.3 | Rekeningschema importeren |  | 0.5h | 2004-01-29 14:30 | 2004-01-29 15:00 | 49 | 252.06d | 0.09d |
| 51 | 2.2.2.5 | Boekingsgroepen en boekingsinstellingen bepalen |  | 1.25h | 2004-01-29 13:30 | 2004-01-29 14:45 | 48 | 251.97d | 0d |
| 52 | 2.2.2.6 | BTW-boekingsgroepen en BTW-boekingsinstellingen bepalen |  | 1h | 2004-01-29 14:45 | 2004-01-29 15:45 | 51 | 251.97d | 0d |
| 53 | 2.2.2.7 | Rekeningschema bijwerken |  | 0.5h | 2004-01-29 15:45 | 2004-01-29 16:15 | 52, 51, 50 | 251.97d | 0d |
| 54 | 2.2.2.8 | Tabel met valutacodes bijwerken |  | 0.25h | 2004-01-29 16:15 | 2004-01-29 16:30 | 53 | 251.97d | 0d |
| 55 | 2.2.2.9 | Bankrekeningen en bankboekingsgroepen maken |  | 0.5h | 2004-01-29 16:30 | 2004-01-29 17:00 | 54, 51 | 251.97d | 0d |
| 56 | 2.2.2.10 | Praktijkoefening - boeken naar grootboek |  | 1h | 2004-01-30 08:00 | 2004-01-30 09:00 | 55 | 251.97d | 0d |
| 57 | 2.2.2.11 | Praktijkoefening - budget |  | 1h | 2004-01-30 09:00 | 2004-01-30 10:00 | 56 | 251.97d | 0d |
| 58 | 2.2.2.12 | Praktijkoefening - rapportageschema’s |  | 1h | 2004-01-30 10:00 | 2004-01-30 11:00 | 57 | 251.97d |  |
| 59 | 2.2.2.13 | Voorbereiding dag 3 |  | 1h | 2004-01-29 11:30 | 2004-01-29 13:30 |  | 252.78d |  |

Notes:
- 27: Dit 2+5+2-concept is een projectsjabloon voor elk Navision-implementatieproject in fase 1. / Het is geen volledig projectplan, maar een sjabloon waarop u verder kunt bouwen. / Als u nieuwe projecten plant, kunt u dit projectplan als uitgangspunt gebruiken en het plan verder uitbreiden met zaken waarvan u weet dat de klant deze ook nodig heeft. / Volg de structuur en beschrijf precies hoe taken moeten worden verwerkt. / Met enige ervaring kunt u, of kan de MBS-partner voor wie u werkt, standaardprojectsjablonen voor uw klant bouwen.
- 28: Situatie vooraf: / Actie: / Situatie achteraf: / Taken voor het personeel van de klant:
- 29: Breng de kennis die is verzameld tijdens het verkoopproces over van de verkoopmanager naar de implementatieconsultant of het implementatieteam. / Zo voorkomt u dat via de vragenlijst dezelfde vragen worden gesteld aan de klant.Maak een voorstel voor een schema en plan de resources die nodig zijn. / Bedenk extra vragen die mogelijk moeten worden gesteld aan de klant.
- 31: Situatie vooraf: / De kennisoverdracht van de verkoper naar de consultant is voltooid. / De installatie-cd en klantlicentie liggen klaar in het zicht van de klant. / Actie: / Opening van de bijeenkomst: / - Wie is wie. / - De klant stelt het bedrijf kort voor aan de consultant. / - De klant geeft aan wat zijn verwachtingen zijn ten aanzien van het project. / - De consultant geeft een overzicht van het totale project en de implementatietaken. / - De consultant geeft aan wat de verwachtingen zijn ten aanzien van de taken van de klant. / - De consultant geeft aan wat de taken zijn voor de dag. / - De consultant biedt de klant de vragenlijst(en) aan. / Bedrijfsgegevens / Grootboek / Verkoop en debiteuren / Inkoop en crediteuren / Voorraad / Relatiebeheer / Vaste activa / - De consultant laat de klant kennismaken met Navision. / - Men bereikt overeenstemming over het projectplan. / - Men bereikt overeenstemming over de trainingscursussen. / Situatie achteraf: / De klant weet wat de volgende stappen zijn en heeft een overzicht over het proces. / De consultant heeft de klant enigszins leren kennen. / Taken voor het personeel van de klant: / De vragenlijst(en) invullen
- 32: Situatie vooraf: / De klant heeft een pc of server voorbereid voor de Navision-software en de database. / Het is een pc of server met Windows 98 of hoger en minimaal 500 MB vrije schijfruimte. / Actie: / Navision Server installeren / Navision Client installeren / De CRONUS Demo-database importeren / De klantlicentie importeren / Het bedrijf van de klant aanmaken en het bedrijfstype selecteren / Situatie achteraf: / De database is gereed in een netwerkomgeving. / Taken voor het personeel van de klant: / Clients distribueren naar andere pc's
- 33: Situatie vooraf: / De vragenlijstbestanden zijn beschikbaar. / De klant heeft de vragenlijst van de kennismakingsbijeenkomst ingevuld. / Actie: / De vragenlijst(en) doorlopen / De vragenlijst(en) aftekenen / De vragenlijst(en) op schijf opslaan / Situatie achteraf: / De vragenlijst is gereed en kan worden geïmporteerd. / Taken voor het personeel van de klant:
- 34: Situatie vooraf: / De Navision Client Server-omgeving is geïnstalleerd (sandbox). / Het bedrijf is aangemaakt. / De klant heeft de vragenlijst van de kennismakingsbijeenkomst ingevuld. / Actie: / De vragenlijst(en) importeren / De vragenlijst(en) valideren / Antwoorden toepassen op de vragenlijst(en) / Situatie achteraf: / De klantendatabase is gereed voor implementatie. / Taken voor het personeel van de klant:
- 35: Situatie vooraf: / Alle taken in de eerste bijeenkomst met de klant zijn voltooid (behalve deze). / Actie: / Een samenvatting geven van de taken van de klant tot aan de volgende stap in het project / De agenda voor de volgende vergadering vaststellen / Een datum afspreken voor de volgende vergadering / Situatie achteraf: / De klant weet nu wat de volgende stap zal zijn. / Taken voor het personeel van de klant:
- 38: Situatie vooraf: / Het personeel van de klant woont de vergadering bij. / Actie: / De consultant of projectmanager leidt de kick off-vergadering waarin het volgende aan de orde komt: / - Doel van het project / - Verwachtingen ten aanzien van het resultaat / - Verwachte werklast voor iedere werknemer / - Basisregels voor het project * / Situatie achteraf: / Het personeel van de klant weet wat er te gebeuren staat, is klaar om aan het project te beginnen en weet hoe samen te werken met de consultant. / Taak voor de manager van het personeel van de klant: / Zorgen dat alle werknemers gemotiveerd zijn om aan het project te werken / * Basisregels kunnen zijn: / - Werkuren (begin/einde/lunch) / - Verwachte voorbereiding / - Factureringsregels (uren/vervoer/hotels) (in het bijzonder voor projecten met een vaste prijs) / - De afhandeling van afwijkingen van het project / - Wie neemt de beslissing over te factureren uren die buiten het bereik van het project vallen? / - Enzovoort
- 39: Situatie vooraf: / Geen / Actie: / Het personeel van de klant een korte training geven zodat dit vertrouwd raakt met de begrippen Gebruikers, Aanmelden, Rollen en Toegangsrechten / Het personeel van de klant Navision-documentatie verstrekken over het onderwerp / Situatie achteraf: / Het personeel van de klant beschikt over basiskennis en trainingsmateriaal. / Taken voor het personeel van de klant: / Gebruikers maken en toegangsrechten instellen
- 40: Situatie vooraf: / Werkbladen zijn gemaakt in onderwerp 9 (2e dag - voorbereiding). / Het personeel van de klant (Verkoop, Inkoop, Grootboek, Voorraad) neemt deel. / Actie: / Werkbladen tonen en uitleggen hoe gegevens in de werkbladen moeten worden ingevuld / Bepalen welke gegevens moeten worden gemigreerd / Algemene richtlijnen voor het invullen van werkbladen: / - Methode 1: vul de gegevens in een geëxporteerd werkblad (18 voor de klant) in. / - Methode 2: vul de gegevens in werkblad 1 in en maak veldverwijzingen in het geëxporteerde werkblad. / - Bedenk dat er stamgegevenssjablonen zijn waarmee het invullen van werkbladen wordt vereenvoudigd. / - Wijzig de volgorde van de kolommen in het geëxporteerde werkblad NIET. / - Zorg dat de lengte van gegevens in een veld de in de veldeigenschappen vastgelegde lengte NIET overschrijdt. / De klant is hiervoor verantwoordelijk voordat de gegevens worden geïmporteerd. / Informatie geven over het opvragen van F1-hulp voor velden (zoeken in de database, een veld zoeken misschien met Ctrl F8, een waarde zoeken, F1.) en misschien een werkblad maken en afdrukken met alle F1-hulp die beschikbaar is / Voorbeelden geven van ingevulde werkbladen / Laat zien hoe de kolommen moeten worden opgemaakt, zodat deze overeenkomen met de veldopties. Hiermee voorkomt u dat het personeel van de klant gegevens invoert die niet kunnen worden geïmporteerd. / Situatie achteraf: / Het personeel van de klant is in staat gegevensbladen te maken. / Taken voor het personeel van de klant: / Werkbladen voor migratie van stamgegevens maken
- 41: Situatie vooraf: / Werkbladen zijn gemaakt in onderwerp 9 (2e dag- voorbereiding). / Het personeel van de klant (Verkoop, Inkoop, Grootboek, Voorraad) neemt deel. / Actie: / De functionaliteit van de stamgegevenssjablonen uitleggen / Bestaande stamgegevenssjablonen als volgt valideren: / a. door sjablonen aan te passen aan de eisen van de klant / b. door de benodigde extra stamgegevenssjablonen te maken / Bepalen voor welke andere tabellen stamgegevenssjablonen kunnen worden gebruikt / Situatie achteraf: / De benodigde stamgegevenssjablonen zijn gemaakt. / Taken voor het personeel van de klant: / Gebruikers laten zien hoe deze stamgegevenssjablonen moeten gebruiken in combinatie met stamgegevensmigratie
- 42: Situatie vooraf: / Beheerders hebben training gehad in het gebruik van werkbladen met stamgegevens. / Actie: / - Vaststellen wie bij de klant verantwoordelijk is voor elk werkblad (klant, leverancier, voorraadbeheer, boekhouding, contactpersonen) / - Deadlines voor het voltooien van de werkbladen afspreken / Situatie achteraf: / Het personeel van de klant is op de hoogte van de taken en deadlines. / Taken voor het personeel van de klant: / De werkbladen invullen
- 43: Situatie vooraf: / Het personeel van de klant (Verkoop, Inkoop, Grootboek, Voorraad) neemt deel. / Actie: / Basistraining voor selecteren en afdrukken van een rapport. / Standaardrapporten (afdrukken) van Navision doornemen voor alle gebieden in de licentie. / Alle rapporten afdrukken en overhandigen aan de klant. / LET OP Wijzigingen in rapporten zijn niet opgenomen in het projectschema 2+5+2. / Situatie achteraf: / Het personeel van de klant is op de hoogte van standaardrapportagevoorzieningen van Navision. / Taken voor het personeel van de klant:
- 44: Situatie vooraf: / Het personeel van de klant heeft beslissingsbevoegdheid. / De MBS-partner heeft toegang tot het Navision-gebruikerstrainingscentrum (niet specifiek). / Actie: / Een vergadering beleggen met een besluitvormer van de klant over trainingscursussen / Verplichte trainingscursussen: / - Basis Financieel / - Basis Verkoop en debiteuren / - Basis Inkoop en crediteuren / - Basis Voorraad / Optionele trainingscursussen (voor uitbreidingen naar fase één) / - Basis CRM - Marketing &amp; Sales / - Productie / - Magazijnbeheer / - Geavanceerde cursussen / Situatie achteraf: / Er zijn datums en namen vastgelegd voor elke trainingscursus. / Taken voor het personeel van de klant: / Ervoor zorgen dat deelnemers weten wanneer en waar de cursussen worden gehouden / Ervoor zorgen dat deelnemers ook daadwerkelijk aan de cursussen deelnemen
- 45: Situatie vooraf: Dag 1 afgerond Actie: Datum voor dag 2 afspreken met projectmanager van klant Voorbereiding van dag 2 Situatie achteraf: Taken voor het personeel van de klant:
- 47: Training zoals gedefinieerd op dag 1
- 48: Situatie vooraf: / Dag 2 is afgerond. / Actie: / Een basisinleiding geven in de functionaliteit van het grootboek en rekeningschema in Navision / Het basistrainingsproces voortzetten / Het personeel begeleiden bij het maken van een rekeningschema / Situatie achteraf: / Het personeel van de klant weet nu hoe het een rekeningschema moet maken en importeren. / Taken voor het personeel van de klant:
- 49: Situatie vooraf: / De sandbox-omgeving is beschikbaar. / Actie: / Bepalen of er een stamgegevenssjabloon voor grootboekrekeningen kan worden gemaakt / Als dat het geval is, deze sjabloon maken / Situatie achteraf: / Taken voor het personeel van de klant:
- 50: Situatie vooraf: / Het Excel-werkblad voor stamgegevens is door de klant ingevuld. / Actie: / Het migratieoverzicht openen en het werkblad importeren / De problemen oplossen die in de migratiematrix worden weergegeven / De stamgegevenssjabloon selecteren / Foutloze gegevens invoeren / Tip: groepeer stamgegevens op stamgegevenssjabloon en importeer de gegevens sjabloon voor sjabloon. / Hiermee vermindert u de hoeveelheid gegevens die uit de werkbladen moet worden geïmporteerd aanzienlijk. / Situatie achteraf: / De items zijn in de Navision-database geïmporteerd. / Taken voor het personeel van de klant: / Controleren of de geïmporteerde gegevens juist zijn
- 51: Situatie vooraf: / Het personeel van de klant beschikt over kennis op het gebied van Grootboek / Klanten / Leveranciers / Voorraad. / Actie: / - Kennis over boekingsgroepen opfrissen / - De behoeften van het bedrijf op het gebied van boekingsgroepen bespreken / - De benodigde boekingsgroepen invoeren op grond van de indeling van het rekeningschema / - De benodigde boekingsinstellingen opgeven / Situatie achteraf: / De klant heeft op schrift gezet wat er over boekingsgroepen is besloten. / Taken voor het personeel van de klant: / - Alle benodigde boekingsgroepen maken / - De boekingsinstellingen opgeven
- 52: Situatie vooraf: / De klant is bekend met het grootboek en de nationale BTW-regelgeving. / Actie: / - Kennis over BTW-boekingsgroepen opfrissen / - De behoeften van bedrijf ten aanzien van BTW-boekingen bespreken / - Op basis van de BTW-regelgeving de benodigde boekingsgroepen invoeren / - De benodigde boekingsinstellingen opgeven / Situatie achteraf: / De klant heeft op schrift gezet wat er over boekingsgroepen is besloten.
- 53: Situatie vooraf: / Het personeel van de klant beschikt over kennis op het gebied van Grootboek / Klanten / Leveranciers / Voorraad. / Actie: / - Wensen voor Navision bespreken / - De volgende velden waar nodig invoeren (bijwerken): Bedrijfsboekingsgroep, Prod.-boekingsgroep, BTW-soort, BTW-bedrijfsboekingsgroep, BTW-productboekingsgroep / Taken voor het personeel van de klant: / - Rekeningschema in zijn geheel bijwerken
- 54: Situatie vooraf: / Het personeel van de klant beschikt over kennis op het gebied van Grootboek / Klanten / Leveranciers / Voorraad. / Actie: / - Velden invoeren (bijwerken) die te maken hebben met gerealiseerde en niet-gerealiseerde winsten en verliezen / Taken voor het personeel van de klant: / - Tabel met valutacodes bijwerken
- 55: Situatie vooraf: / Het personeel van de klant beschikt over kennis op het gebied van Grootboek / Klanten / Leveranciers / Voorraad. / Actie: / - Bankrekeningen voor het bedrijf invoeren / Taken voor het personeel van de klant: / - Extra bankrekeningen invoeren indien nodig
- 56: Situatie vooraf: / Het personeel van de klant beschikt over kennis op het gebied van Grootboek / Klanten / Leveranciers / Voorraad. / Actie: / - Gegevens invoeren in de financiële dagboeken / - Testen of de BTW goed wordt berekend / - Een testrapport afdrukken / - Boeken / - Controleren of grootboekposten en BTW-boekingen kloppen / - Grootboekrapporten maken: Balans - Proefbalans Detail / - Het rekeningschema filteren / - Navigeren / Het personeel van de klant moet gegevens invoeren onder toezicht van de consultant / Situatie achteraf: / Het personeel van de klant verzamelt steeds meer basiskennis die nodig is voor dagelijks terugkerende taken. / Taken voor het personeel van de klant: / Oefenen, oefenen, oefenen...
- 57: Situatie vooraf: / Het personeel van de klant beschikt over kennis op het gebied van Grootboek / Klanten / Leveranciers / Voorraad. / Actie: / - Gegevens invoeren in de budgetschema s / - Grootboekrapporten maken: Balans/Budget / - Filteren in budgetschema s / - Gegevens exporteren naar Excel en importeren uit Excel / Het personeel van de klant moet gegevens invoeren onder toezicht van de consultant / Situatie achteraf: / Het personeel van de klant verzamelt steeds meer basiskennis over dagelijks terugkerende budgetteringstaken. / Taken voor het personeel van de klant: / Oefenen, oefenen, oefenen...
- 58: Situatie vooraf: / Het personeel van de klant beschikt over kennis op het gebied van Grootboek / Klanten / Leveranciers / Voorraad. / Actie: / Gegevens (sjabloon) invoeren in het rapportageschema / De indeling van kolommen instellen / Gegevens exporteren naar Excel / Het rapportageschema afdrukken / Het personeel van de klant moet gegevens invoeren onder toezicht van de consultant. / Situatie achteraf: / Het personeel van de klant verzamelt basiskennis over het uitvoeren van dagelijks terugkerende taken. / Taken voor het personeel van de klant: / Oefenen, oefenen, oefenen...
- 59: Situatie vooraf: / Dag 2 afgerond / Actie: / Datum voor dag 3 afspreken met projectmanager van klant / Voorbereiding van dag 3 / Situatie achteraf: / Taken voor het personeel van de klant:

| ID | WBS | Task | Type | Duration | Start | Finish | Predecessors | Total slack | Free slack |
| --- | --- | --- | --- | --- | --- | --- | --- | --- | --- |
| 60 | 2.2.3 | **Dag 3 klant/leverancier** |  | 0.88d | 2004-01-30 11:00 | 2004-02-02 10:00 | 46 | 251.97d | 0d |
| 61 | 2.2.3.1 | Procestraining Basis Verkoop en debiteuren | milestone | 0h | 2004-01-30 11:00 | 2004-01-30 11:00 |  | 252.84d |  |
| 62 | 2.2.3.2 | Procestraining Basis Inkoop en crediteuren | milestone | 0h | 2004-01-30 11:00 | 2004-01-30 11:00 |  | 252.84d |  |
| 63 | 5.1.2.3.3 | Stamgegevens valideren - klant |  | 1h | 2004-01-30 11:00 | 2004-01-30 12:00 |  | 252.72d |  |
| 64 | 5.1.2.3.4 | Stamgegevenssjablonen valideren - leverancier |  | 1h | 2004-01-30 11:00 | 2004-01-30 12:00 |  | 252.72d |  |
| 65 | 2.2.3.3 | Stamgegevens importeren |  | 0.25h | 2004-01-30 11:00 | 2004-01-30 11:15 |  | 251.97d | 0d |
| 66 | 2.2.3.5 | **Klant-/verkoopgegevens** |  | 0.5d | 2004-01-30 11:15 | 2004-01-30 16:15 | 65 | 251.97d |  |
| 67 | 2.2.3.5.1 | Boekingsgroepen voor verkoop instellen |  | 0.5h | 2004-01-30 11:15 | 2004-01-30 11:45 |  | 251.97d | 0d |
| 68 | 2.2.3.5.2 | Verkoopparameters instellen |  | 0.5h | 2004-01-30 11:45 | 2004-01-30 13:15 | 67 | 251.97d | 0d |
| 69 | 2.2.3.5.3 | De velden van de klantenkaart doorlopen |  | 0.5h | 2004-01-30 13:15 | 2004-01-30 13:45 | 68 | 251.97d | 0d |
| 70 | 2.2.3.5.4 | Codes en provisie van de verkoper |  | 0.25h | 2004-01-30 13:45 | 2004-01-30 14:00 | 69 | 251.97d | 0d |
| 71 | 2.2.3.5.5 | Factuurkorting |  | 0.25h | 2004-01-30 14:00 | 2004-01-30 14:15 | 70 | 251.97d | 0d |
| 72 | 2.2.3.5.6 | Prijsgroepen |  | 0.5h | 2004-01-30 14:15 | 2004-01-30 14:45 | 71 | 251.97d | 0d |
| 73 | 2.2.3.5.7 | Klantenkorting |  | 0.5h | 2004-01-30 14:45 | 2004-01-30 15:15 | 72 | 251.97d | 0d |
| 74 | 2.2.3.5.8 | Betalingscondities |  | 0.25h | 2004-01-30 15:15 | 2004-01-30 15:30 | 73 | 251.97d | 0d |
| 75 | 2.2.3.5.9 | Rentefactuurconditie |  | 0.25h | 2004-01-30 15:30 | 2004-01-30 15:45 | 74 | 251.97d | 0d |
| 76 | 2.2.3.5.10 | Verzendcodes en expediteurs |  | 0.25h | 2004-01-30 15:45 | 2004-01-30 16:00 | 75 | 251.97d | 0d |
| 77 | 2.2.3.5.11 | Verzendadressen |  | 0.25h | 2004-01-30 16:00 | 2004-01-30 16:15 | 76 | 251.97d | 0d |
| 78 | 2.2.3.6 | **Leveranciers-/inkoopgegevens** |  | 0.34d | 2004-01-30 16:15 | 2004-02-02 10:00 | 77 | 251.97d |  |
| 79 | 2.2.3.6.1 | Boekingsgroepen voor verkoop instellen |  | 0.5h | 2004-01-30 16:15 | 2004-01-30 16:45 |  | 251.97d | 0d |
| 80 | 2.2.3.6.2 | Inkoopparameters instellen |  | 0.25h | 2004-01-30 16:45 | 2004-01-30 17:00 | 79 | 251.97d | 0d |
| 81 | 2.2.3.6.3 | Velden met leveranciersgegevens bekijken |  | 0.25h | 2004-02-02 08:00 | 2004-02-02 08:15 | 80 | 251.97d | 0d |
| 82 | 2.2.3.6.4 | Inkopercodes |  | 0.25h | 2004-02-02 08:15 | 2004-02-02 08:30 | 81 | 251.97d | 0d |
| 83 | 2.2.3.6.5 | Factuurkorting |  | 0.25h | 2004-02-02 08:30 | 2004-02-02 08:45 | 82 | 251.97d | 0d |
| 84 | 2.2.3.6.6 | Orderadressen |  | 0.25h | 2004-02-02 08:45 | 2004-02-02 09:00 | 83 | 251.97d | 0d |
| 85 | 2.2.3.6.7 | Artikelcatalogus leverancier |  | 0.25h | 2004-02-02 09:00 | 2004-02-02 09:15 | 84 | 251.97d | 0d |
| 86 | 2.2.3.6.8 | Inkoopprijzen |  | 0.5h | 2004-02-02 09:15 | 2004-02-02 09:45 | 85 | 251.97d | 0d |
| 87 | 2.2.3.6.9 | Regelkorting |  | 0.25h | 2004-02-02 09:45 | 2004-02-02 10:00 | 86 | 251.97d |  |

Notes:
- 61: Training zoals gedefinieerd op dag 1
- 62: Training zoals gedefinieerd op dag 1
- 63: Situatie vooraf: / Werkbladen zijn gemaakt in onderwerp 9 (2e dag - voorbereiding). / Het personeel van de klant (Verkoop) neemt deel. / Actie: / Uitleggen hoe stamgegevenssjablonen werken / Bestaande stamgegevenssjablonen als volgt valideren: / a. door sjablonen aan te passen aan de eisen van de klant / b. door de benodigde extra stamgegevenssjablonen te maken / Bepalen voor welke andere tabellen stamgegevenssjablonen kunnen worden gebruikt / Situatie achteraf: / De benodigde stamgegevenssjablonen zijn gemaakt. / Taken voor het personeel van de klant: / Gebruikers laten zien hoe deze stamgegevenssjablonen moeten gebruiken in combinatie met stamgegevensmigratie
- 64: Situatie vooraf: / Werkbladen zijn gemaakt in onderwerp 9 (2e dag - voorbereiding). / Het personeel van de klant (Inkoop) neemt deel. / Actie: / De functionaliteit van de stamgegevenssjablonen uitleggen / Bestaande stamgegevenssjablonen als volgt valideren: / a. door sjablonen aan te passen aan de eisen van de klant / b. door de benodigde extra stamgegevenssjablonen te maken / Bepalen voor welke andere tabellen stamgegevenssjablonen kunnen worden gebruikt / Situatie achteraf: / De benodigde stamgegevenssjablonen zijn gemaakt. / Taken voor het personeel van de klant: / Gebruikers laten zien hoe deze stamgegevenssjablonen moeten gebruiken in combinatie met stamgegevensmigratie
- 65: Situatie vooraf: / Het Excel-werkblad voor stamgegevens is door de klant ingevuld. / Actie: / Het migratieoverzicht openen en het werkblad importeren / Problemen oplossen die in de migratiematrix worden weergegeven / De stamgegevenssjabloon selecteren / Foutloze gegevens invoeren / Tip: groepeer stamgegevens op stamgegevenssjabloon en importeer de gegevens sjabloon voor sjabloon. / Hiermee vermindert u de hoeveelheid gegevens die uit de werkbladen moet worden geïmporteerd aanzienlijk. / Situatie achteraf: / Items zijn in de Navision-database geïmporteerd. / Taken voor het personeel van de klant: / Controleren of de geïmporteerde gegevens juist zijn
- 67: Situatie vooraf: / Het personeel van de klant beschikt over kennis op het gebied van Grootboek / Klanten / Leveranciers / Klanten. / Actie: / - De kennis over boekingsgroepen opfrissen / - De behoeften van het bedrijf op het gebied van boekingsgroepen bespreken / - De benodigde grootboekrekeningen in de boekingsgroepen invullen / Situatie achteraf: / De klant heeft op schrift gezet wat er over boekingsgroepen is besloten. / Taken voor het personeel van de klant: / - Alle benodigde boekingsgroepen maken / - Boekingsgroepen aan een klantenkaart koppelen / (dit kan ook worden gedaan in het Excel-werkblad dat vervolgens opnieuw moet worden geïmporteerd) / - Testen of het boeken correct werkt tijdens het factureren
- 68: Situatie vooraf: / Klant beschikt over kennis op het gebied van grootboek/verkoop. / Actie: / Benodigde parameters selecteren en invullen / Situatie achteraf: / Verkoopsysteem werkt correct. / Taken voor het personeel van de klant:
- 69: Situatie vooraf: / Het personeel van de klant heeft kennis op het gebied van Grootboek / Verkoop en maakt geregeld nieuwe klanten aan / Actie: / Uitleg geven bij alle velden op één specifieke klantenkaart / Situatie achteraf: / Taken voor het personeel van de klant:
- 70: Situatie vooraf: / Het personeel van de klant heeft kennis op het gebied van verkoop en provisie en weet bijvoorbeeld hoeveel provisie kan worden berekend voor welke verkopers. / Actie: / De codes van de verkoper maken en het benodigde percentage provisie koppelen / Situatie achteraf: / Na het boeken van facturen kan er een rapport worden afgedrukt waarin de berekende provisie voor iedere verkoper wordt weergegeven. / Taken voor het personeel van de klant:
- 71: Situatie vooraf: / Het personeel van de klant heeft kennis op verkoopgebied en weet wanneer klanten korting krijgen en hoeveel. / Actie: / - Factuurkortingsgroepen maken en de kortingspercentages invullen / - De boekingsinstellingen controleren voor de rekening waarop de factuurkorting moet worden geboekt / Situatie achteraf: / De factuurkorting wordt automatisch berekend en geboekt wanneer een klant wordt gefactureerd. / Taken voor het personeel van de klant:
- 72: Situatie vooraf: / Het personeel van de klant weet hoe het prijzensysteem werkt en weet bijvoorbeeld hoeveel verschillende prijslijsten er worden gebruikt, wat de prijzen zijn enzovoort. / Actie: / Prijsgroepen maken en aan de klantenkaart koppelen / Situatie achteraf: / Wanneer een verkooporder wordt gemaakt, wordt automatisch de juiste prijs voor het artikel opgezocht. / Taken voor het personeel van de klant:
- 73: Situatie vooraf: / Het personeel van de klant beschikt over kennis op verkoopgebied en weet wanneer klanten korting krijgen en hoeveel. / Actie: / - Klantenkortingsgroepen maken en de kortingspercentages invullen / - De boekingsinstellingen controleren voor de rekening waarop de regelkorting moet worden geboekt / Situatie achteraf: / Het percentage regelkorting wordt automatisch berekend en op de verkoopregel geplaatst bij het maken van een order. / Taken voor het personeel van de klant:
- 74: Situatie vooraf: / Het personeel van de klant beschikt over kennis op verkoopgebied en weet of er betalingscondities gelden, welke betalingscondities worden gebruikt en waarop de korting moet worden geboekt. / Actie: / - Betalingscondities maken met datumformules en kortingspercentages / Situatie achteraf: / Bij het maken van een document voor een klant, worden de vervaldatum en, indien van toepassing, de contantkorting automatisch berekend. / Taken voor het personeel van de klant:
- 75: Situatie vooraf: / Het personeel van de klant beschikt over kennis op verkoopgebied en weet welke rentefactuurcondities er worden gebruikt, als deze worden gebruikt. / Actie: / Gegevens aanmaken die zijn verbonden met rentefactuurcondities, zoals rentepercentage en rekeningnummer. / Situatie achteraf: / Personeel van de klant kan rentefacturen maken, die kunnen worden geboekt of naar klanten kunnen worden verzonden. / Taken voor het personeel van de klant:
- 76: Situatie vooraf: / Het personeel van de klant beschikt over kennis op verkoopgebied en weet welke expediteurs en verzendcodes worden gebruikt. / Actie: / - Verzendcodes maken / - Expediteurs met internetadressen opgeven / Situatie achteraf: / Bij het boeken van een factuur wordt de omschrijving van de verzending op de verzendingen en facturen afgedrukt. De code van de expediteur kan worden gebruikt voor ordertracering via internet. / Taken voor het personeel van de klant:
- 77: Situatie vooraf: / Het personeel van de klant beschikt over kennis op verkoopgebied en weet of de klanten verzendadressen gebruiken. / Actie: / Verzendadressen opgeven / Situatie achteraf: / Verzendadressen kunnen handmatig of automatisch aan verkoopdocumenten worden toegevoegd om goederen naar een ander adres te verzenden dan naar het adres van de klant zelf. / Taken voor het personeel van de klant:
- 79: Situatie vooraf: / Het personeel van de klant beschikt over kennis op het gebied van Grootboek / Klanten / Leveranciers. / Actie: / - Kennis over boekingsgroepen opfrissen / - Boekingsbehoeften van het bedrijf bespreken / - Benodigde grootboekrekeningen invoeren in boekingsgroepen / Situatie achteraf: / De klant heeft op schrift gezet wat er over boekingsgroepen is besloten. / Taken voor het personeel van de klant: / - Alle benodigde boekingsgroepen maken / - Boekingsgroepen koppelen aan klanten / (dit kan ook worden gedaan in het Excel-werkblad dat vervolgens opnieuw moet worden geïmporteerd) / - Controleren of boeken bij factureren goed verloopt
- 80: Situatie vooraf: / Klant beschikt over kennis op het gebied van Grootboek / Inkoop. / Actie: / Benodigde parameters selecteren en invullen / Situatie achteraf: / Inkoopsysteem werkt correct. / Taken voor het personeel van de klant:
- 81: Situatie vooraf: / Het personeel van de klant beschikt over kennis op het gebied van grootboek/inkoop en maakt geregeld leveranciers aan. / Actie: / Uitleg geven bij alle velden op één specifieke leverancierskaart / Situatie achteraf: / Taken voor het personeel van de klant:
- 82: Situatie vooraf: / Het personeel van de klant beschikt over kennis op het gebied van grootboek/inkoop / Actie: / Inkopercodes maken / Situatie achteraf: / Taken voor het personeel van de klant:
- 83: Situatie vooraf: / Het personeel van de klant beschikt over kennis op het gebied van inkoop en weet hoeveel korting leveranciers geven en wanneer. / Actie: / - Factuurkortingsgroepen maken en de kortingspercentages invoeren / - De boekingsinstellingen voor de rekening controleren voor het boeken van factuurkorting / Situatie achteraf: / De factuurkorting wordt automatisch berekend en geboekt bij het boeken van een factuur van een leverancier. / Taken voor het personeel van de klant:
- 84: Situatie vooraf: / Het personeel van de klant beschikt over kennis op het gebied van inkoop en weet of leveranciers orderadressen gebruiken. / Actie: / Orderadressen opgeven / Situatie achteraf: / Orderadressen kunnen handmatig of automatisch in inkoopdocumenten worden ingevoerd om goederen te bestellen bij een ander adres dan dat van de leverancier zelf. / Taken voor het personeel van de klant:
- 85: Situatie vooraf: / Het personeel van de klant beschikt over kennis op het gebied van inkoop. / Actie: / De lijst met artikelnummers van de leverancier opgeven / Situatie achteraf: / Het is nu mogelijk om de lijst met artikelnummers van de leverancier te vergelijken met die van uzelf. U kunt rapporten zo instellen dat de artikelnummers van de leverancier in plaats van uw eigen nummers worden gebruikt (bijvoorbeeld inkoopoffertes). / Taken voor het personeel van de klant:
- 86: Situatie vooraf: / Het personeel van de klant weet hoe het prijzensysteem werkt. Het kent bijvoorbeeld de prijzen van iedere leverancier, of er een minimumafname is vereist enzovoort. / Actie: / Prijsgroepen maken voor iedere leverancier / Situatie achteraf: / Bij het maken van een inkooporder wordt automatisch de juiste prijs voor een artikel ingevoerd. / Taken voor het personeel van de klant:
- 87: Situatie vooraf: / Het personeel van de klant beschikt over kennis op het gebied van inkoop en weet hoeveel korting wordt verleend door leveranciers en wanneer deze korting wordt verleend. / Actie: / - Kortingen invoeren, inclusief minimumaantal, begindatum enzovoort / - De boekingsinstellingen controleren voor de rekening voor het boeken van regelkorting / Situatie achteraf: / Het percentage voor de regelkorting wordt automatisch berekend en op de inkoopregel geplaatst wanneer er een order wordt gemaakt. / Taken voor het personeel van de klant:

| ID | WBS | Task | Duration | Start | Finish | Predecessors | Total slack | Free slack |
| --- | --- | --- | --- | --- | --- | --- | --- | --- |
| 88 | 2.2.4 | **Dag 4 - voorraad** | 0.97d | 2004-02-02 10:00 | 2004-02-03 09:45 | 60 | 251.97d | 0d |
| 89 | 2.2.4.1 | Procestraining Basis Voorraad | 0.5h | 2004-02-02 10:00 | 2004-02-02 10:30 |  | 252.88d |  |
| 90 | 2.2.4.2 | Producentencodes maken | 0.25h | 2004-02-02 10:00 | 2004-02-02 10:15 |  | 251.97d | 0d |
| 91 | 2.2.4.3 | Artikelcategoriecodes definiëren | 0.25h | 2004-02-02 10:15 | 2004-02-02 10:30 | 90 | 251.97d | 0d |
| 92 | 2.2.4.4 | Productgroepen definiëren | 0.25h | 2004-02-02 10:30 | 2004-02-02 10:45 | 91 | 251.97d | 0d |
| 93 | 2.2.4.5 | Artikeltraceringscodes definiëren | 0.25h | 2004-02-02 10:45 | 2004-02-02 11:00 | 92 | 251.97d | 0d |
| 94 | 2.2.4.6 | Locaties definiëren | 0.25h | 2004-02-02 11:00 | 2004-02-02 11:15 | 93 | 251.97d | 0d |
| 95 | 2.2.4.7 | Artikelkortingsgroepen definiëren | 1h | 2004-02-02 11:15 | 2004-02-02 13:15 | 94 | 251.97d | 0d |
| 96 | 2.2.4.8 | Parameters instellen en implementeren | 0.25h | 2004-02-02 13:15 | 2004-02-02 13:30 | 95 | 251.97d | 0d |
| 97 | 2.2.4.9 | Stamgegevens importeren | 0.5h | 2004-02-02 13:30 | 2004-02-02 14:00 | 96 | 251.97d | 0d |
| 98 | 2.2.4.11 | Geïmporteerde stamgegevens controleren | 2h | 2004-02-02 14:00 | 2004-02-02 16:00 | 97 | 251.97d | 0d |
| 99 | 2.2.4.12 | Artikelvertalingen | 0.25h | 2004-02-02 16:00 | 2004-02-02 16:15 | 98 | 251.97d | 0d |
| 100 | 2.2.4.13 | Niet-afgehandelde problemen | 2.5h | 2004-02-02 16:15 | 2004-02-03 09:45 | 99 | 251.97d |  |
| 101 | 2.2.5 | **Dag 5 - verkoop en inkoop** | 0.88d | 2004-02-03 09:45 | 2004-02-04 08:45 | 88 | 251.97d |  |
| 102 | 2.2.5.1 | **Verkoopprocedures** | 0.5d | 2004-02-03 09:45 | 2004-02-03 14:45 |  | 251.97d | 0d |
| 103 | 5.1.2.5.1.1 | Procestraining - verkoop | 0.5h | 2004-02-03 09:45 | 2004-02-03 10:15 |  | 252.66d |  |
| 104 | 2.2.5.1.1 | Velden van een verkooporder bekijken | 0.5h | 2004-02-03 09:45 | 2004-02-03 10:15 |  | 251.97d | 0d |
| 105 | 2.2.5.1.2 | Testverkooporders maken - order afdrukken | 0.5h | 2004-02-03 10:15 | 2004-02-03 10:45 | 104 | 251.97d | 0d |
| 106 | 2.2.5.1.3 | Verzenden - verzending afdrukken | 0.25h | 2004-02-03 10:45 | 2004-02-03 11:00 | 105 | 251.97d | 0d |
| 107 | 2.2.5.1.4 | Factuur - factuur afdrukken | 0.25h | 2004-02-03 11:00 | 2004-02-03 11:15 | 106 | 251.97d | 0d |
| 108 | 2.2.5.1.5 | Creditnota | 0.25h | 2004-02-03 11:15 | 2004-02-03 11:30 | 107 | 251.97d | 0d |
| 109 | 2.2.5.1.6 | Batchboeken verkooporders | 0.25h | 2004-02-03 11:30 | 2004-02-03 11:45 | 108 | 251.97d | 0d |
| 110 | 2.2.5.1.7 | Offerte | 0.25h | 2004-02-03 11:45 | 2004-02-03 12:00 | 109 | 251.97d | 0d |
| 111 | 2.2.5.1.8 | Raamcontracten | 0.25h | 2004-02-03 13:00 | 2004-02-03 13:15 | 110 | 251.97d | 0d |
| 112 | 2.2.5.1.9 | Aanmaningen | 1h | 2004-02-03 13:15 | 2004-02-03 14:15 | 111 | 251.97d | 0d |
| 113 | 2.2.5.1.10 | Alle transacties verwijderen | 0.25h | 2004-02-03 14:15 | 2004-02-03 14:30 | 112 | 251.97d | 0d |
| 114 | 2.2.5.1.11 | Nummerreeksen opnieuw instellen | 0.25h | 2004-02-03 14:30 | 2004-02-03 14:45 | 113 | 251.97d | 0d |

Notes:
- 89: Training zoals gedefinieerd op dag 1
- 90: Situatie vooraf: / Het personeel van de klant beschikt over kennis op het gebied van voorraadbeheer en verwante onderwerpen. / Actie: / - Wensen ten aanzien van producentencodes en eventuele gevolgen bespreken / Situatie achteraf: / De klant heeft de producentencodes op schrift gezet. / Taken voor het personeel van de klant: / - Alle benodigde producentencodes invoeren
- 91: Situatie vooraf: / Het personeel van de klant beschikt over kennis op het gebied van voorraadbeheer en verwante onderwerpen. / Actie: / - Wensen ten aanzien van artikelcategoriecodes en eventuele gevolgen bespreken / Situatie achteraf: / De klant heeft de artikelcategoriecodes op schrift gezet. / Taken voor het personeel van de klant: / - Alle benodigde artikelcategoriecodes invoeren
- 92: Situatie vooraf: / Het personeel van de klant beschikt over kennis op het gebied van voorraadbeheer en verwante onderwerpen. / Actie: / - Wensen ten aanzien van productgroepen en eventuele gevolgen bespreken / Situatie achteraf: / De klant heeft de productgroepen op schrift gezet. / Taken voor het personeel van de klant: / - Alle benodigde productgroepen invoeren
- 93: Situatie vooraf: / Het personeel van de klant beschikt over kennis op het gebied van voorraadbeheer en verwante onderwerpen. / Actie: / - Wensen ten aanzien van artikeltraceringscodes en eventuele gevolgen bespreken / Situatie achteraf: / De klant heeft de artikeltraceringscodes op schrift gezet. / Taken voor het personeel van de klant: / - Alle benodigde artikeltraceringscodes invoeren
- 94: Situatie vooraf: / Het personeel van de klant beschikt over kennis op het gebied van voorraadbeheer en verwante onderwerpen. / Actie: / - Wensen ten aanzien van locaties en eventuele gevolgen bespreken / Situatie achteraf: / De klant heeft de locaties op schrift gezet. / Taken voor het personeel van de klant: / Alle benodigde locaties maken
- 95: Situatie vooraf: / Het personeel van de klant beschikt over kennis op het gebied van voorraadbeheer, verkoop en het kortingsbeleid van het bedrijf. / Actie: / - Wensen ten aanzien van artikelkortingsgroepen en eventuele gevolgen bespreken / Situatie achteraf: / De klant heeft de artikelkortingsgroepen op schrift gezet. / Taken voor het personeel van de klant: / - Alle benodigde artikelkortingsgroepen maken
- 96: Situatie vooraf: / De voorraadvragenlijst is ingevuld door de klant, dus zijn alle voorraadinstellingen beschikbaar in Excel. / Actie: / Open het implementatieprogramma, kies Quest.data. Typ het pad en de naam van het bestand met de vragenlijst. Kies Importeren. / Situatie achteraf: / De voorraadinstellingen zijn geïmporteerd in de Navision-database. / Taken voor het personeel van de klant: / Controleren of geïmporteerde gegevens juist zijn
- 97: Situatie vooraf: / Het Excel-werkblad voor stamgegevens is ingevuld door de klant. / Actie: / Het migratieoverzicht openen en het werkblad importeren / De problemen oplossen die in de migratiematrix worden weergegeven / De stamgegevenssjabloon selecteren / Foutloze gegevens invoeren / Tip: groepeer stamgegevens op stamgegevenssjabloon en importeer de gegevens sjabloon voor sjabloon. / Hiermee vermindert u de hoeveelheid gegevens die uit de werkbladen moet worden geïmporteerd aanzienlijk. / Situatie achteraf: / De items zijn in de Navision-database geïmporteerd / Taken voor het personeel van de klant: / Controleren of de geïmporteerde gegevens juist zijn
- 98: Situatie vooraf: / Excel-werkblad met stamgegevens is geïmporteerd in de Navision-database. / Validatie is afgerond. / Actie: / Aan de hand van artikelgegevens controleren of de geïmporteerde gegevens juist zijn / Situatie achteraf: / Geïmporteerde gegevens zijn gecontroleerd. / Taken voor het personeel van de klant: / Geïmporteerde gegevens controleren
- 99: Situatie vooraf: / Excel-werkblad met stamgegevens is geïmporteerd in de Navision-database. / Validatie is afgerond. / Actie: / Artikelvertalingen maken / Situatie achteraf: / Artikelomschrijvingen vertaald naar alle relevante talen. / Taken voor het personeel van de klant: / Artikelomschrijvingen vertalen
- 100: Situatie vooraf: / Er bestaan enkele niet-afgehandelde problemen / Actie: / Situatie achteraf: / Taken voor het personeel van de klant:
- 103: Training zoals gedefinieerd op dag 1
- 104: Situatie vooraf: / Klant heeft deelgenomen aan inleidende cursus Navision. / Klant heeft deelgenomen aan cursus over verkoopgedeelte van Navision. / Periodieke activiteiten met betrekking tot aanmaningen zijn afgehandeld. / Actie: / Velden op tabbladen van formulier met verkoopkop bespreken / Velden van formulier met verkoopregels bespreken / Situatie achteraf: / Taken voor het personeel van de klant:
- 105: Situatie vooraf: / Dag 1, 2, 3 en 4 zijn afgerond en alle basisgegevens zijn ingevoerd. / Actie: / - Een verkooporder maken met minimaal 2 artikelregels voor een binnenlandse klant / - Een verkooporder maken met minimaal 2 artikelregels voor een klant in de EU / - Een verkooporder maken met minimaal 2 artikelregels voor een klant buiten de EU / - De artikelbeschikbaarheid controleren / - Prijzen, kortingen, betalingscondities, leveringsvoorwaarden, BTW, gewicht, volume, aantal colli en afmetingen controleren / - Regels maken in de 3 orders met grootboekrekeningen / - Regels maken in de 3 orders met alleen tekst / - Orders afdrukken / Situatie achteraf: / Taken voor het personeel van de klant: / - Relevante voorbeelden van bestaande verkooporders verzamelen / - Prijzen, kortingen, betalingscondities, leveringsvoorwaarden, BTW, gewicht, volume, aantal colli en afmetingen controleren / - De afgedrukte orders controleren / Taken voor het personeel van de klant:
- 106: Situatie vooraf: / De drie hiervoor genoemde verkooporders moeten beschikbaar zijn / Actie: / Voor elke verkooporder: / 1 artikelregel volledig verzenden / 1 artikelregel gedeeltelijk verzenden / Boeken - Controlelijst / Boeken F11 / Situatie achteraf: / Geboekte verzendingen controleren / Verzendingen afdrukken / Navigeren - Geboekte posten controleren / Taken voor het personeel van de klant:
- 107: Situatie vooraf: / De hiervoor genoemde verkooporders moeten beschikbaar zijn / Actie: / Voor elke verkooporder: / 1 artikelregel volledig factureren / 1 artikelregel gedeeltelijk factureren / Boeken - Controlelijst / Boeken F11 / Orders volledig boeken / Situatie achteraf: / Geboekte facturen controleren / Facturen afdrukken / Navigeren - Geboekte posten controleren / Taken voor het personeel van de klant:
- 108: Situatie vooraf: / Actie: / Verkoopcreditnota maken / Boeken - Controlelijst / Boeken F11 / Situatie achteraf: / Geboekte creditnota controleren / Creditnota afdrukken / Navigeren - Geboekte posten controleren / Taken voor het personeel van de klant:
- 109: Situatie vooraf: / Actie: / 2 - 4 verkooporders maken Boeken, batchboeken, verkoopordernummers invullen op aanvraagformulier van rapport / Rapport uitvoeren, opties op tabblad Rapport toelichten / Uitleggen wat te doen bij melding dat niet alle orders zijn geboekt / Situatie achteraf: / Taken voor het personeel van de klant:
- 110: Situatie vooraf: Actie: Verkoopofferte maken Order maken Situatie achteraf: Taken voor het personeel van de klant:
- 111: Situatie vooraf: Actie: Verkoopraamcontract maken Order maken Situatie achteraf: Taken voor het personeel van de klant:
- 112: Situatie vooraf: / Klant maakt gebruik van aanmaningen. / Actie: / Werkdag instellen op eerdere datum / Verkooporders maken / Verkooporders verzenden en factureren / Werkdag instellen op vandaag / Aanmaningen maken / Afdrukken - controlelijst / Aanmaning verzenden / Aanmaning afdrukken / Situatie achteraf: / Taken voor het personeel van de klant:
- 113: Situatie vooraf: Actie: Implementatieprogramma, tabblad Data cleaning, knop Clean Situatie achteraf: Taken voor het personeel van de klant:
- 114: Situatie vooraf: / Actie: / Alle nummerreeksen moeten opnieuw worden ingesteld, bijvoorbeeld omdat ze bij een hoger nummer moeten beginnen / Situatie achteraf: / Taken voor het personeel van de klant:

| ID | WBS | Task | Type | Duration | Start | Finish | Predecessors | Total slack | Free slack |
| --- | --- | --- | --- | --- | --- | --- | --- | --- | --- |
| 115 | 2.2.5.2 | **Inkoopprocedures** |  | 0.38d | 2004-02-03 14:45 | 2004-02-04 08:45 | 114 | 251.97d |  |
| 116 | 5.1.2.5.2.1 | Procestraining - inkoop |  | 0.5h | 2004-02-03 14:45 | 2004-02-03 15:15 |  | 252.28d |  |
| 117 | 2.2.5.2.1 | Velden van een inkooporder bekijken |  | 0.5h | 2004-02-03 14:45 | 2004-02-03 15:15 |  | 251.97d | 0d |
| 118 | 2.2.5.2.2 | Testinkooporders maken - order afdrukken |  | 0.25h | 2004-02-03 15:15 | 2004-02-03 15:30 | 117 | 251.97d | 0d |
| 119 | 2.2.5.2.3 | Ontvangen - ontvangstbewijs afdrukken |  | 0.25h | 2004-02-03 15:30 | 2004-02-03 15:45 | 118 | 251.97d | 0d |
| 120 | 2.2.5.2.4 | Factuur - factuur afdrukken |  | 0.25h | 2004-02-03 15:45 | 2004-02-03 16:00 | 119 | 251.97d | 0d |
| 121 | 2.2.5.2.5 | Creditnota |  | 0.25h | 2004-02-03 16:00 | 2004-02-03 16:15 | 120 | 251.97d | 0d |
| 122 | 2.2.5.2.6 | Batchboeken inkooporders |  | 0.25h | 2004-02-03 16:15 | 2004-02-03 16:30 | 121 | 251.97d | 0d |
| 123 | 2.2.5.2.7 | Offerte |  | 0.25h | 2004-02-03 16:30 | 2004-02-03 16:45 | 122 | 251.97d | 0d |
| 124 | 2.2.5.2.8 | Raamcontract |  | 0.5h | 2004-02-03 16:45 | 2004-02-04 08:15 | 123 | 251.97d | 0d |
| 125 | 2.2.5.2.9 | Alle transacties verwijderen |  | 0.25h | 2004-02-04 08:15 | 2004-02-04 08:30 | 124 | 251.97d | 0d |
| 126 | 2.2.5.2.10 | Nummerreeksen opnieuw instellen |  | 0.25h | 2004-02-04 08:30 | 2004-02-04 08:45 | 125 | 251.97d |  |
| 127 | 2.2.5.3 | Openingssaldi voor klanten, leveranciers, voorraad en grootboek |  | 1h | 2004-02-03 14:45 | 2004-02-03 15:45 | 102 | 252.22d |  |
| 128 | 5.2 | **Training & afdrukken** |  | 0d | 2004-01-13 08:30 | 2004-01-13 08:30 |  | 268d |  |
| 129 | 5.2.1 | Training van eindgebruikers | milestone | 0h | 2004-01-13 08:30 | 2004-01-13 08:30 |  | 268d |  |
| 130 | 5.2.2 | Lijsten & documenten | milestone | 0h | 2004-01-13 08:30 | 2004-01-13 08:30 |  | 268d |  |
| 131 | 5.2.3 | Training eindgebruikers - productie | milestone | 0h | 2004-01-13 08:30 | 2004-01-13 08:30 |  | 268d |  |
| 132 | 5.2.4 | Training eindgebruikers - magazijn | milestone | 0h | 2004-01-13 08:30 | 2004-01-13 08:30 |  | 268d |  |
| 133 | 5.3 | **Uitbreidingen** |  | 1.12d | 2004-01-13 08:30 | 2004-01-14 09:30 |  | 266.88d |  |
| 134 | 5.3.1 | **Eerste dag Vaste activa** |  | 1.12d | 2004-01-13 08:30 | 2004-01-14 09:30 |  | 266.88d |  |
| 135 | 5.3.1.1 | Procestraining Vaste activa | milestone | 0h | 2004-01-13 08:30 | 2004-01-13 08:30 |  | 266.88d | 0d |
| 136 | 5.3.1.2 | De vragenlijst over vaste activa aftekenen |  | 1h | 2004-01-13 08:30 | 2004-01-13 09:30 | 135 | 266.88d | 0d |
| 137 | 5.3.1.3 | De stamgegevenssjabloon valideren |  | 1h | 2004-01-13 09:30 | 2004-01-13 10:30 | 136 | 266.88d | 0d |
| 138 | 5.3.1.4 | VA-boekingsgroepen bepalen |  | 1h | 2004-01-13 10:30 | 2004-01-13 11:30 | 137 | 266.88d | 0d |
| 139 | 5.3.1.5 | VA-classificaties bepalen |  | 1h | 2004-01-13 11:30 | 2004-01-13 13:30 | 138 | 266.88d | 0d |
| 140 | 5.3.1.6 | Een afschrijvingsboek en -tabellen maken |  | 1h | 2004-01-13 13:30 | 2004-01-13 14:30 | 139 | 266.88d | 0d |
| 141 | 5.3.1.7 | VA-dagboeken maken |  | 1h | 2004-01-13 14:30 | 2004-01-13 15:30 | 140 | 266.88d | 0d |
| 142 | 5.3.1.8 | Import van vaste activa |  | 1h | 2004-01-13 15:30 | 2004-01-13 16:30 | 141 | 266.88d | 0d |
| 143 | 5.3.1.9 | Een besluit nemen over de verzekeringssoort en verzekeringsdagboeken |  | 1h | 2004-01-13 16:30 | 2004-01-14 08:30 | 142 | 266.88d | 0d |
| 144 | 5.3.1.10 | Een besluit namen over onderhoud |  | 1h | 2004-01-14 08:30 | 2004-01-14 09:30 | 143 | 266.88d |  |

Notes:
- 116: Training zoals gedefinieerd op dag 1
- 117: Situatie vooraf: / Actie: / Een nieuwe inkooporder maken. / Velden op tabbladen van formulier met inkoopkop bespreken. / Velden van formulier met inkoopregels bespreken. / Situatie achteraf: / Taken voor het personeel van de klant:
- 118: Situatie vooraf: / Dag 1, 2, 3 en 4 zijn afgerond en alle basisgegevens zijn ingevoerd. / Actie: / - Een verkooporder maken met minimaal 2 artikelregels voor een binnenlandse klant / - Een verkooporder maken met minimaal 2 artikelregels voor een klant in de EU / - Een verkooporder maken met minimaal 2 artikelregels voor een klant buiten de EU / - De artikelbeschikbaarheid controleren / - Prijzen, kortingen, betalingscondities, leveringsvoorwaarden, BTW, gewicht, volume, aantal colli en afmetingen controleren / - Regels maken in de 3 orders met grootboekrekeningen / - Regels maken in de 3 orders met alleen tekst / - Orders afdrukken / Situatie achteraf: / Taken voor het personeel van de klant: / - Relevante voorbeelden van bestaande verkooporders verzamelen / - Prijzen, kortingen, betalingscondities, leveringsvoorwaarden, BTW, gewicht, volume, aantal colli en afmetingen controleren / - De afgedrukte orders controleren
- 119: Situatie vooraf: / De drie hiervoor genoemde inkooporders moeten beschikbaar zijn / Actie: / Voor elke inkooporder: / 1 artikelregel volledig ontvangen / 1 artikelregel gedeeltelijk ontvangen / Boeken - Controlelijst / Boeken F11 / Situatie achteraf: / Geboekte ontvangsten controleren / Ontvangstbewijzen afdrukken / Navigeren - Geboekte posten controleren / Taken voor het personeel van de klant:
- 120: Situatie vooraf: / De drie hiervoor genoemde inkooporders moeten beschikbaar zijn / Actie: / Voor elke inkooporder: / 1 artikelregel volledig factureren / 1 artikelregel gedeeltelijk factureren / Boeken - Controlelijst / Boeken F11 / Orders volledig boeken / Situatie achteraf: / Geboekte facturen controleren / Facturen afdrukken / Navigeren - Geboekte posten controleren / Taken voor het personeel van de klant:
- 121: Situatie vooraf: / Actie: / Een inkoopcreditnota maken / Boeken - Controlelijst / Boeken F11 / Situatie achteraf: / Geboekte creditnota controleren / De creditnota afdrukken / Navigeren - Geboekte posten controleren / Taken voor het personeel van de klant:
- 122: Situatie vooraf: / Actie: / 2 - 4 inkooporders maken / Boeken, batchboeken, inkoopordernummers invullen op aanvraagformulier van rapport / Rapport uitvoeren / Uitleggen wat te doen bij melding dat niet alle orders zijn geboekt / Situatie achteraf: / Taken voor het personeel van de klant:
- 123: Situatie vooraf: / Klant beschikt over kennis op inkoopgebied. / Actie: / Inkoopofferte maken / Order maken / Situatie achteraf: / Taken voor het personeel van de klant:
- 124: Situatie vooraf: / Actie: / Inkoopraamcontract maken / Order maken / Situatie achteraf: / Taken voor het personeel van de klant:
- 125: Situatie vooraf: / Actie: / Implementatieprogramma, tabblad Data cleaning, knop Clean / Situatie achteraf: / Taken voor het personeel van de klant:
- 126: Situatie vooraf: / Actie: / Alle nummerreeksen moeten opnieuw worden ingesteld, bijvoorbeeld omdat ze bij een hoger nummer moeten beginnen / Situatie achteraf: / Taken voor het personeel van de klant:
- 127: Situatie vooraf: / Klant beschikt over een lijst met de saldi en voorraad. / Actie: / Verkoopdagboek maken / Inkoopdagboek maken / Inventarisatiedagboek maken / Financieel dagboek maken / Dagboeken testen en controleren / Dagboeken boeken / Geboekte posten controleren / Rapporten uitvoeren met saldi en voorraad / Situatie achteraf: / Taken voor het personeel van de klant:
- 129: Training zoals gedefinieerd op dag 1
- 130: Situatie vooraf: / Het personeel van de klant (Verkoop, Inkoop, Grootboek, Voorraad) neemt deel. / Standaardlijsten zijn geïntroduceerd op dag 1. / Standaardlijsten zijn onvoldoende. / Actie: / Een overzicht maken van specifieke lijsten en documenten die de klant nodig heeft / Functionele specificatievereisten maken voor elke lijst in het overzicht / Prijs en levering voor klantspecifieke lijsten aanbieden / LET OP! Wijzigingen in lijsten zijn niet opgenomen in het projectschema 2+5+2. / Situatie achteraf: / Klantspecifieke lijsten worden gemaakt, afgeleverd, getest en goedgekeurd door de klant. / Taken voor het personeel van de klant:
- 131: Training zoals gedefinieerd op dag 1
- 132: Training zoals gedefinieerd op dag 1
- 135: Training zoals gedefinieerd op dag 1
- 136: Situatie vooraf: / De vragenlijst over vaste activa die in Navision is gemaakt, is beschikbaar. / Actie: / De vragenlijst(en) doorlopen / De vragenlijst(en) aftekenen / De vragenlijst(en) op schijf opslaan / Situatie achteraf: / De vragenlijst kan worden geïmporteerd. / Taken voor het personeel van de klant:
- 137: Situatie vooraf: / Het personeel van de klant (Financiën) neemt deel. / Actie: / - Uitleggen hoe stamgegevenssjablonen werken / - Bepalen welke stamgegevenssjablonen nodig zijn / - De benodigde extra stamgegevenssjablonen maken / Situatie achteraf: / De benodigde stamgegevenssjablonen voor vaste activa zijn gemaakt. / Taken voor het personeel van de klant: / Gebruikers laten zien hoe deze stamgegevenssjablonen moeten gebruiken in combinatie met stamgegevensmigratie
- 138: Situatie vooraf: / Het personeel van de klant beschikt over kennis op het gebied van grootboek en vaste activa. / Actie: / - Kennis over boekingsgroepen opfrissen / - De behoeften van het bedrijf op het gebied van boekingsgroepen bespreken / - De benodigde boekingsgroepen invoeren op grond van de indeling van het rekeningschema / - De benodigde boekingsinstellingen opgeven / Situatie achteraf: / De klant heeft op schrift wat er over boekingsgroepen is besloten. / Taken voor het personeel van de klant: / - Alle benodigde boekingsgroepen maken / - De boekingsinstellingen opgeven
- 139: Situatie vooraf: / Het personeel van de klant beschikt over kennis op het gebied van voorraadbeheer en verwante onderwerpen. / Actie: / - Wensen ten aanzien van VA-classificaties en eventuele gevolgen bespreken / Situatie achteraf: / De klant heeft op schrift gezet wat er over VA-classificaties is besloten. / Taken voor het personeel van de klant: / Alle benodigde VA-classificaties maken
- 140: Situatie vooraf: / Het personeel van de klant beschikt over kennis op het gebied van voorraadbeheer en verwante onderwerpen. / Actie: / - De wensen ten aanzien van een afschrijvingsboek en -tabellen en eventuele gevolgen bespreken / Situatie achteraf: / De klant heeft op schrift gezet wat er over afschrijvingsboeken en -tabellen is besloten. / Taken voor het personeel van de klant: / Het benodigde afschrijvingsboek en de benodigde afschrijvingstabellen maken
- 141: Situatie vooraf: / Het personeel van de klant beschikt over kennis op het gebied van voorraadbeheer en verwante onderwerpen. / Actie: / - De wensen ten aanzien van VA-dagboeken en eventuele gevolgen bespreken / Situatie achteraf: / De klant heeft op schrift gezet wat er over VA-dagboeken is besloten. / Taken voor het personeel van de klant: / Alle benodigde VA-dagboeken maken
- 142: Situatie vooraf: / Het Excel-werkblad voor stamgegevens is door de klant ingevuld. / Actie: / Het migratieoverzicht openen en het werkblad importeren / De problemen die in de migratiematrix worden weergegeven, oplossen / De stamgegevenssjabloon selecteren / Foutloze gegevens invoeren / Tip: groepeer stamgegevens op stamgegevenssjabloon en importeer de gegevens sjabloon voor sjabloon. / Hiermee vermindert u de hoeveelheid gegevens die uit de werkbladen moet worden geïmporteerd aanzienlijk. / Situatie achteraf: / De items zijn in de Navision-database geïmporteerd. / Taken voor het personeel van de klant: / Controleren of de geïmporteerde gegevens juist zijn
- 143: Situatie vooraf: / Het personeel van de klant beschikt over kennis op het gebied van voorraadbeheer en verwante onderwerpen. / Actie: / - De wensen ten aanzien van de verzekeringssoort en verzekeringsdagboeken en de gevolgen ervan bespreken / Situatie achteraf: / De klant heeft op schrift gezet wat er over de verzekeringssoort en verzekeringsdagboeken is besloten. / Taken voor het personeel van de klant: / De verzekeringssoort en alle verzekeringsdagboeken maken
- 144: Situatie vooraf: / Het personeel van de klant beschikt over kennis op het gebied van voorraadbeheer en verwante onderwerpen. / Actie: / - de wensen ten aanzien van onderhoud en de gevolgen ervan bespreken / Situatie achteraf: / De klant heeft op schrift gezet wat er over onderhoud is besloten. / Taken voor het personeel van de klant: / Alle benodigde onderhoud vastleggen

| ID | WBS | Task | Type | Duration | Start | Finish | Predecessors | Total slack | Free slack |
| --- | --- | --- | --- | --- | --- | --- | --- | --- | --- |
| 145 | 5.3.2 | **Eerste dag CRM - Marketing & Sales** |  | 0.75d | 2004-01-13 08:30 | 2004-01-13 15:30 |  | 267.25d |  |
| 146 | 5.3.2.1 | Procestraining Marketing | milestone | 0h | 2004-01-13 08:30 | 2004-01-13 08:30 |  | 267.25d | 0d |
| 147 | 5.3.2.2 | De vragenlijst over CRM - Marketing & Sales-instellingen aftekenen |  | 1h | 2004-01-13 08:30 | 2004-01-13 09:30 | 146 | 267.25d | 0d |
| 148 | 5.3.2.3 | Stamgegevenssjablonen valideren |  | 1h | 2004-01-13 09:30 | 2004-01-13 10:30 | 147 | 267.25d | 0d |
| 149 | 5.3.2.4 | Een besluit nemen over mailinggroepen |  | 1h | 2004-01-13 10:30 | 2004-01-13 11:30 | 148 | 267.25d | 0d |
| 150 | 5.3.2.5 | Een besluit nemen over de campagnestatus |  | 1h | 2004-01-13 11:30 | 2004-01-13 13:30 | 149 | 267.25d | 0d |
| 151 | 5.3.2.6 | Een besluit nemen over een profielvragenlijst |  | 1h | 2004-01-13 13:30 | 2004-01-13 14:30 | 150 | 267.25d | 0d |
| 152 | 5.3.2.7 | Contactpersonen importeren |  | 1h | 2004-01-13 14:30 | 2004-01-13 15:30 | 151 | 267.25d |  |
| 153 | 1 | **Uitbreidingen voor middelgrote projecten** |  | 21.28d? | 2004-01-13 08:30 | 2004-02-11 10:45 |  | 246.72d |  |
| 154 | 3.1 | **+ 5 dagen productie** |  | 9.31d? | 2004-01-13 08:30 | 2004-01-26 11:00 |  | 246.72d | 0d |
| 155 | 3.1.1 | **Dag 1 voorbereiding voor productie** |  | 1d? | 2004-01-13 08:30 | 2004-01-14 08:30 |  | 255.03d |  |
| 156 | 5.4.1.1.1 | Kick off-vergadering Productie |  | 8h? | 2004-01-13 08:30 | 2004-01-14 08:30 |  | 255.03d |  |
| 157 | 5.4.1.1.2 | Implementatieoverwegingen Productie |  | 8h? | 2004-01-13 08:30 | 2004-01-14 08:30 |  | 255.03d |  |
| 158 | 5.4.1.1.3 | Productie - artikel/vraag |  | 8h? | 2004-01-13 08:30 | 2004-01-14 08:30 |  | 255.03d |  |
| 159 | 5.4.1.1.4 | De klant kennis laten maken met het gegevensmigratieconcept |  | 8h? | 2004-01-13 08:30 | 2004-01-14 08:30 |  | 255.03d |  |
| 160 | 3.1.2 | **Dag 2+3 - productie-instellingen** |  | 7.53d? | 2004-01-13 08:30 | 2004-01-22 13:45 |  | 246.72d |  |
| 161 | 5.4.1.2.1 | Vragenlijst over productie-instellingen aftekenen |  | 8h? | 2004-01-13 08:30 | 2004-01-14 08:30 |  | 255.03d |  |
| 162 | 5.4.1.2.2 | Productie - stamgegevens van artikel |  | 8h? | 2004-01-13 08:30 | 2004-01-14 08:30 |  | 255.03d |  |
| 163 | 5.4.1.2.3 | Definitie van productiestamgegevens |  | 8h? | 2004-01-13 08:30 | 2004-01-14 08:30 |  | 255.03d |  |
| 164 | 3.1.2.4 | Stuklijsten en bewerkingsplannen definiëren |  | 1h | 2004-01-13 08:30 | 2004-01-13 09:30 |  | 246.72d | 0d |
| 165 | 5.4.1.2.5 | Bewerkingsplankoppelingen definiëren |  | 8h? | 2004-01-13 09:30 | 2004-01-14 09:30 | 164 | 246.72d | 0d |
| 166 | 5.4.1.2.6 | Procesgerichte stamgegevens definiëren |  | 8h? | 2004-01-14 09:30 | 2004-01-15 09:30 | 165 | 246.72d | 0d |
| 167 | 5.4.1.2.7 | Productieschema |  | 8h? | 2004-01-15 09:30 | 2004-01-16 09:30 | 166 | 246.72d | 0d |
| 168 | 5.4.1.2.8 | Productieprognosenamen |  | 8h? | 2004-01-16 09:30 | 2004-01-19 09:30 | 167 | 246.72d | 0d |
| 169 | 5.4.1.2.9 | Capaciteitseenheden definiëren |  | 8h? | 2004-01-19 09:30 | 2004-01-20 09:30 | 168 | 246.72d | 0d |
| 170 | 5.4.1.2.10 | Ploegen definiëren |  | 8h? | 2004-01-20 09:30 | 2004-01-21 09:30 | 169 | 246.72d | 0d |

Notes:
- 146: Training zoals gedefinieerd op dag 1
- 147: Situatie vooraf: / De implementatievragenlijst voor CRM - Marketing &amp; Sales die in Navision is gemaakt, is beschikbaar. / Actie: / De vragenlijst(en) doorlopen / De vragenlijst(en) aftekenen / De vragenlijst(en) op schijf opslaan. / Situatie achteraf: / De vragenlijst kan worden geïmporteerd. / Taken voor het personeel van de klant:
- 148: Situatie vooraf: / Het personeel van de klant (Verkoop) neemt deel. / Het personeel van de klant beschikt over kennis op het gebied van verkoop, CRM - Marketing &amp; Sales en verwante gebieden. / Actie: / De functionaliteit van de stamgegevenssjablonen uitleggen / Bestaande stamgegevenssjablonen valideren voor contactpersonen / Bepalen voor welke doeleinden stamgegevenssjablonen kunnen worden gebruikt / De benodigde extra stamgegevenssjablonen maken / Situatie achteraf: / De benodigde extra stamgegevenssjablonen voor contactpersonen zijn gemaakt. / Taken voor het personeel van de klant: / Gebruikers laten zien hoe deze stamgegevenssjablonen moeten gebruiken in combinatie met stamgegevensmigratie
- 149: Situatie vooraf: / Het personeel van de klant (Verkoop) neemt deel. / Het personeel van de klant beschikt over kennis op het gebied van verkoop, CRM - Marketing &amp; Sales en verwante gebieden. / Actie: / De functionaliteit van mailinggroepen uitleggen / Bestaande mailinggroepen valideren / Besluiten welke extra mailinggroepen mogelijk moeten worden gemaakt / De benodigde extra mailinggroepen maken / Situatie achteraf: / De benodigde mailinggroepen zijn gemaakt. / Taken voor het personeel van de klant:
- 150: Situatie vooraf: / Het personeel van de klant (Verkoop) neemt deel. / Het personeel van de klant beschikt over kennis op het gebied van verkoop, CRM - Marketing &amp; Sales en verwante gebieden. / Actie: / De functionaliteit van de campagnestatus uitleggen / De bestaande campagnestatus valideren / Bepalen of een extra campagnestatus nodig is / De benodigde extra campagnestatus maken / Situatie achteraf: / De benodigde extra campagnestatus is gemaakt. / Taken voor het personeel van de klant:
- 151: Situatie vooraf: / Het personeel van de klant (Verkoop) neemt deel. / Het personeel van de klant beschikt over kennis op het gebied van verkoop, CRM - Marketing &amp; Sales en verwante gebieden. / Actie: / De functionaliteit van een profielvragenlijst uitleggen / De bestaande profielvragenlijst valideren / Bepalen of er mogelijk een extra profielvragenlijst nodig is / De benodigde extra profielvragenlijst maken / Situatie achteraf: / Het personeel van de klant weet hoe het een profielvragenlijst kan maken. / Taken voor het personeel van de klant: / Extra profielvragenlijsten maken
- 152: Situatie vooraf: / Het personeel van de klant (Verkoop) neemt deel. / Het personeel van de klant beschikt over kennis op het gebied van verkoop, CRM - Marketing &amp; Sales en verwante gebieden. / Het Excel-werkblad voor stamgegevens is door de klant ingevuld. / Actie: / Het migratieoverzicht openen en het werkblad importeren / De problemen die in de migratiematrix worden weergegeven, oplossen / De stamgegevenssjabloon selecteren / Foutloze gegevens invoeren / Tip: groepeer stamgegevens op stamgegevenssjabloon en importeer de gegevens sjabloon voor sjabloon. / Hiermee vermindert u de hoeveelheid gegevens die uit de werkbladen moet worden geïmporteerd aanzienlijk. / Situatie achteraf: / De items zijn in de Navision-database geïmporteerd. / Taken voor het personeel van de klant: / Controleren of de geïmporteerde gegevens juist zijn
- 156: Situatie vooraf: / Het personeel van de klant neemt deel aan de vergadering. / Actie: / De consultant of projectmanager leidt de kick off-vergadering waarin het volgende aan de orde komt: / - Doel van het project / - Verwachtingen ten aanzien van het resultaat / - Verwachte werklast voor iedere werknemer / - Basisregels voor het project * / Situatie achteraf: / Het personeel van de klant weet wat er te gebeuren staat, is klaar om aan het project te beginnen en weet hoe samen te werken met de consultant. / Taak voor de manager van het personeel van de klant: / Zorgen dat alle werknemers gemotiveerd zijn om aan het project te werken / * Basisregels kunnen zijn: / - Werkuren (begin/einde/lunch) / - Verwachte voorbereiding / - Factureringsregels (uren/vervoer/hotels) (in het bijzonder voor projecten met een vaste prijs) / - De afhandeling van afwijkingen van het project / - Wie neemt de beslissing over te factureren uren die buiten het bereik van het project vallen? / - Enzovoort
- 157: Situatie vooraf: / De productiemanager van de klant neemt deel. / Er is documentatie voor de huidige werkstroom aanwezig. / Er zijn vereisten opgesteld voor essentiële procedures. / Actie: / Een analyse maken van de huidige werkstroom van de klant om op basis daarvan Navision Manufacturing in te stellen / Situatie achteraf: / Er is een analyserapport gemaakt waarin wordt beschreven hoe Navision Manufacturing moet worden ingesteld. / Taken voor het personeel van de klant: / Instellingsgegevens invoeren
- 158: Artikelen: / Productiespecifieke instellingen voor het artikel / Planning van de vraag / Orderplanning gebruiken / Het niveau-voor-niveau-principe / Impact op beschikbaarheid / Koppelingen tussen vraag en levering
- 159: Situatie vooraf: / Er zijn werkbladen gemaakt in onderwerp 9 (tweede dag van de voorbereiding). / Algemene richtlijnen voor het invullen van gegevens in de gegevensbladen: / Situatie achteraf: / Taken voor het personeel van de klant:
- 161: Situatie vooraf: / Er is een vragenlijst over productie-instellingen aanwezig. / Algemene richtlijnen voor het invullen gegevens in werkbladen: / Situatie achteraf: / Taken voor het personeel van de klant:
- 162: Productiespecifiek: / Tabblad Aanvulling / Geproduceerde artikelen / Productiebeleid / Bew.-plannr. / Prod.-stuklijstnr. / Afboekingsmethode / Uitval % / Lotgrootte / Tabblad Planning / Bestelbeleid / Reserveren / Ordertraceringsmethode
- 163: Situatie vooraf: / Het personeel van de klant beschikt over kennis op het gebied van productie en verwante gebieden. / Actie: / De noodzaak en gevolgen van een productiekalender bespreken / De noodzaak en gevolgen van afdelingsgroepen bespreken / De noodzaak en gevolgen van afdelingen bespreken / De noodzaak en gevolgen van standaardtaken bespreken / Situatie achteraf: / Er zijn actiepunten op schrift gezet. / Taken voor het personeel van de klant: / - De overeengekomen stamgegevens invoeren
- 164: Situatie vooraf: / Het personeel van de klant beschikt over kennis op het gebied van productie en andere gebieden. / Actie: / De noodzaak en de gevolgen van stuklijsten en bewerkingsplannen bespreken / Mogelijke bewerkingsplankoppelingen definiëren / Situatie achteraf: / De klant heeft op schrift gezet wat er over stuklijsten en bewerkingsplannen (inclusief koppelingen) is besloten. / Taken voor het personeel van de klant: / - Alle benodigde stuklijsten en bewerkingsplannen maken
- 166: Situatie vooraf: / Het personeel van de klant beschikt over kennis op het gebied van productie en andere gebieden. / Actie: / De noodzaak van stopcodes bespreken en stopcodes definiëren / De noodzaak van uitvalcodes bespreken en uitvalcodes definiëren / Capaciteitsbegrensde resources bespreken en deze identificeren / Situatie achteraf: / De klant heeft actiepunten op schrift gezet. / Taken voor het personeel van de klant: / - De overeengekomen procesgerichte stamgegevens maken

| ID | WBS | Task | Duration | Start | Finish | Predecessors | Total slack | Free slack |
| --- | --- | --- | --- | --- | --- | --- | --- | --- |
| 171 | 5.4.1.2.11 | **Stamgegevens** | 1.41d | 2004-01-21 09:30 | 2004-01-22 13:45 | 170 | 246.72d |  |
| 172 | 3.1.2.6 | Stamgegevens importeren | 1h | 2004-01-21 09:30 | 2004-01-21 10:30 |  | 246.72d | 0d |
| 173 | 3.1.2.7 | De geïmporteerde stamgegevens valideren | 1h | 2004-01-21 10:30 | 2004-01-21 11:30 | 172 | 246.72d | 0d |
| 174 | 3.1.2.11 | Stamgegevens van de productieprognose importeren | 0.25h | 2004-01-21 11:30 | 2004-01-21 11:45 | 173 | 246.72d | 0d |
| 175 | 3.1.2.12 | Geïmporteerde stamgegevens van de productieprognose valideren | 1h | 2004-01-21 11:45 | 2004-01-21 13:45 | 174 | 246.72d | 0d |
| 176 | 3.1.2.13 | Stamgegevens van stuklijsten importeren | 0.25h | 2004-01-21 13:45 | 2004-01-21 14:00 | 175 | 246.72d | 0d |
| 177 | 3.1.2.14 | Geïmporteerde stamgegevens van stuklijsten valideren | 2.5h | 2004-01-21 14:00 | 2004-01-21 16:30 | 176 | 246.72d | 0d |
| 178 | 3.1.2.15 | Stamgegevens van de capaciteitseenheid, ploegen, stopcodes, uitvalcodes en codes voor kwaliteitsmetingen importeren | 0.25h | 2004-01-21 16:30 | 2004-01-21 16:45 | 177 | 246.72d | 0d |
| 179 | 3.1.2.16 | Geïmporteerde stamgegevens van de capaciteitseenheid, ploegen, stopcodes, uitvalcodes en codes voor kwaliteitsmetingen valideren | 1h | 2004-01-21 16:45 | 2004-01-22 08:45 | 178 | 246.72d | 0d |
| 180 | 3.1.2.17 | Stamgegevens van de bewerkingsplaats/afdeling importeren (groep) | 0.25h | 2004-01-22 08:45 | 2004-01-22 09:00 | 179 | 246.72d | 0d |
| 181 | 3.1.2.18 | Geïmporteerde stamgegevens van de bewerkingsplaats/afdeling importeren (groep) valideren | 1h | 2004-01-22 09:00 | 2004-01-22 10:00 | 180 | 246.72d | 0d |
| 182 | 3.1.2.19 | Stamgegevens van bewerkingsplannen importeren | 0.25h | 2004-01-22 10:00 | 2004-01-22 10:15 | 181 | 246.72d | 0d |
| 183 | 3.1.2.20 | Geïmporteerde stamgegevens van bewerkingsplannen valideren | 2.5h | 2004-01-22 10:15 | 2004-01-22 13:45 | 182 | 246.72d | 0d |
| 184 | 2.2.5.1 | **Dag 4+5 productie en planningsprocedures** | 1.78d | 2004-01-22 13:45 | 2004-01-26 11:00 |  | 246.72d |  |
| 185 | 2.2.5.1.1 | De velden van een productieorder bekijken | 2h | 2004-01-22 13:45 | 2004-01-22 15:45 | 183 | 246.72d | 0d |
| 186 | 2.2.5.1.2 | Testproductieorders maken - order afdrukken | 2h | 2004-01-22 15:45 | 2004-01-23 08:45 | 185 | 246.72d | 0d |
| 187 | 2.2.5.1.3 | De productieorderstatus wijzigen | 0.5h | 2004-01-23 08:45 | 2004-01-23 09:15 | 186 | 246.72d | 0d |
| 188 | 2.2.5.1.5 | Output en uren boeken | 0.5h | 2004-01-23 09:15 | 2004-01-23 09:45 | 187 | 246.72d | 0d |
| 189 | 2.2.5.1.4 | Materiaalverbruik boeken | 0.5h | 2004-01-23 09:45 | 2004-01-23 10:15 | 188 | 246.72d | 0d |
| 190 | 2.2.5.1.7 | De productieorder voltooien | 2h | 2004-01-23 10:15 | 2004-01-23 13:15 | 189 | 246.72d | 0d |
| 191 | 2.2.5.1.10 | Alle transacties verwijderen | 0.25h | 2004-01-23 13:15 | 2004-01-23 13:30 | 190 | 246.72d | 0d |
| 192 | 2.2.5.1.11 | Nummerreeksen opnieuw instellen | 0.25h | 2004-01-23 13:30 | 2004-01-23 13:45 | 191 | 246.72d | 0d |
| 193 | 3.1.3.9 | Planningsvoorstel - regeneratief plan - MPS | 0.5h | 2004-01-23 13:45 | 2004-01-23 14:15 | 192 | 246.72d | 0d |
| 194 | 3.1.3.10 | Vast geplande productieorder vrijgeven | 0.5h | 2004-01-23 14:15 | 2004-01-23 14:45 | 193 | 246.72d | 0d |
| 195 | 3.1.3.11 | Planningsvoorstel - regeneratief plan - MRP | 0.5h | 2004-01-23 14:45 | 2004-01-23 15:15 | 194 | 246.72d | 0d |
| 196 | 3.1.3.12 | Vast geplande productieorder vrijgeven | 0.5h | 2004-01-23 15:15 | 2004-01-23 15:45 | 195 | 246.72d | 0d |
| 197 | 3.1.3.13 | Magazijnpick | 0.5h | 2004-01-23 15:45 | 2004-01-23 16:15 | 196 | 246.72d | 0d |
| 198 | 3.1.3.14 | Verbruiksdagboek | 0.5h | 2004-01-23 16:15 | 2004-01-23 16:45 | 197 | 246.72d | 0d |
| 199 | 3.1.3.15 | Outputdagboek | 0.5h | 2004-01-23 16:45 | 2004-01-26 08:15 | 198 | 246.72d | 0d |
| 200 | 3.1.3.16 | Interne magazijnopslag | 0.5h | 2004-01-26 08:15 | 2004-01-26 08:45 | 199 | 246.72d | 0d |
| 201 | 3.1.3.17 | Opslag | 0.5h | 2004-01-26 08:45 | 2004-01-26 09:15 | 200 | 246.72d | 0d |
| 202 | 3.1.3.18 | Vrijgegeven PO voltooien | 0.5h | 2004-01-26 09:15 | 2004-01-26 09:45 | 201 | 246.72d | 0d |
| 203 | 3.1.3.19 | Stappen herhalen voor andere orders | 1.25h | 2004-01-26 09:45 | 2004-01-26 11:00 | 202 | 246.72d |  |

Notes:
- 172: Situatie vooraf: / Het Excel-werkblad voor stamgegevens is door de klant ingevuld. / Actie: / Het migratieoverzicht openen en het werkblad importeren / De problemen die in de migratiematrix worden weergegeven, oplossen / De stamgegevenssjabloon selecteren / Foutloze gegevens invoeren / Tip: groepeer stamgegevens op stamgegevenssjabloon en importeer de gegevens sjabloon voor sjabloon. / Hiermee vermindert u de hoeveelheid gegevens die uit de werkbladen moet worden geïmporteerd aanzienlijk. / Tabellen die moeten worden geïmporteerd: / Gegevens van de productieprognose / Stuklijsten / De capaciteitseenheid / Ploegen / Stopcodes / Uitvalcodes / Codes voor kwaliteitsmetingen / Situatie achteraf: / De items zijn in de Navision-database geïmporteerd. / Taken voor het personeel van de klant:
- 173: Situatie vooraf: / Het Excel-werkblad met stamgegevens is in de Navision-database geïmporteerd. / Actie: / De migratiematrix openen en de gegevens valideren / Gegevens van de productieprognose / Stuklijsten / De capaciteitseenheid / Ploegen / Stopcodes / Uitvalcodes / Codes voor kwaliteitsmetingen / Situatie achteraf: / De geïmporteerde stamgegevens zijn gevalideerd. / Taken voor het personeel van de klant: / De gegevens gebruiken
- 185: Situatie vooraf: / De klant heeft deelgenomen aan een inleidende cursus Navision. / De klant heeft deelgenomen aan een cursus over het verkoopgedeelte van Navision. / De klant heeft deelgenomen aan een cursus over productiegrondslagen van Navision. / Periodieke activiteiten met betrekking tot aanmaningen zijn afgehandeld. / Actie: / Alle velden op de tabbladen van het formulier met de verkoopkop bespreken / Alle velden van het formulier met verkoopregels bespreken / Situatie achteraf: / Taken voor het personeel van de klant:
- 186: Situatie vooraf: / Dag 1, 2, 3, 4, 5 en 6 zijn afgerond en alle basisgegevens zijn ingevuld. / Actie: / - Controleren of de artikelen die in de verkoopproceduretest zijn gebruikt, een stuklijst en een bewerkingsplan hebben (is dat niet het geval, maak dan een stuklijst en een bewerkingsplan) / - De voorraadwaarde boeken voor de artikelen die in de stuklijst worden gebruikt / - Drie verkooporders maken via de verkoopprocedures / - Testverkooporders maken met de orderplanning voor vast geplande orders / - De orders afdrukken / - De orders plannen met de grafische planning / Situatie achteraf: / Taken voor het personeel van de klant: / - Relevante voorbeelden van voormalige productieorders verzamelen / - De prijzen en aantallen controleren / - De afgedrukte orders controleren
- 187: Situatie vooraf: / De drie hiervoor vermelde productieorders zijn gemaakt. / Actie: / De status van elke productieorders wijzigen in vrijgegeven / Situatie achteraf: / Taken voor het personeel van de klant:
- 188: Situatie vooraf: / De drie hiervoor vermelde productieorders zijn gemaakt. / Actie: / Voor elke productieorder: / 1 productieorderregel met output en uren volledig boeken / 1 productieorderregel met output en uren gedeeltelijk boeken / Boeken - Controlelijst / Boeken F11 / Situatie achteraf: / Controleer de geboekte output. / Navigeren - de geboekte output controleren / Taken voor het personeel van de klant:
- 189: Situatie vooraf: / De drie hiervoor vermelde productieorders zijn gemaakt. / Actie: / Voor elke productieorder: / 1 productieorderregel met materiaalverbruik volledig boeken / 1 productieorderregel met materiaalverbruik gedeeltelijk boeken / Boeken - Controlelijst / Boeken F11 / Situatie achteraf: / Controleer het geboekte materiaalverbruik. / Navigeren - het geboekte materiaalverbruik controleren / Taken voor het personeel van de klant:
- 190: Situatie vooraf: / De drie hiervoor vermelde productieorders zijn gemaakt. / Actie: / De status van elke productieorder veranderen in voltooid / De batchverwerking Kostprijs herwaarderen - Artikelposten uitvoeren / De batchverwerking Voorraadwaarde boeken uitvoeren / Situatie achteraf: / Controleer de geboekte voorraadwaarde en de resultaten. / Navigeren - De geboekte voorraadwaarde en de resultaten controleren / Taken voor het personeel van de klant:
- 191: Situatie vooraf: Actie: Implementatieprogramma, tabblad Data cleaning, knop Clean Situatie achteraf: Taken voor het personeel van de klant:
- 192: Situatie vooraf: / Actie: / Alle nummerreeksen moeten opnieuw worden ingesteld, bijvoorbeeld omdat ze bij een hoger nummer moeten beginnen / Situatie achteraf: / Taken voor het personeel van de klant:

| ID | WBS | Task | Duration | Start | Finish | Predecessors | Total slack | Free slack |
| --- | --- | --- | --- | --- | --- | --- | --- | --- |
| 204 | 3.2 | **+ 5 dagen magazijnbeheer** | 11.97d? | 2004-01-26 11:00 | 2004-02-11 10:45 | 154 | 246.72d |  |
| 205 | 3.2.1 | **Dag 1 voorbereiding magazijnbeheer** | 1d? | 2004-01-26 11:00 | 2004-01-27 11:00 |  | 246.72d | 0d |
| 206 | 5.4.2.1.1 | Kick off-vergadering - magazijn | 8h? | 2004-01-26 11:00 | 2004-01-27 11:00 |  | 246.72d |  |
| 207 | 5.4.2.1.2 | Overwegingen bij de implementatie van magazijnbeheer | 4h | 2004-01-26 11:00 | 2004-01-26 16:00 |  | 247.22d |  |
| 208 | 5.4.2.1.3 | Overwegingen bij het magazijnbeheerproces | 4h | 2004-01-26 11:00 | 2004-01-26 16:00 |  | 247.22d |  |
| 209 | 3.2.2 | **Dag 2 magazijnbeheerinstellingen** | 1.69d | 2004-01-26 11:00 | 2004-01-28 08:30 |  | 247.72d |  |
| 210 | 2.2.4.8 | Vragenlijst over magazijnbeheerinstellingen aftekenen | 1h | 2004-01-26 11:00 | 2004-01-26 12:00 |  | 258.56d |  |
| 211 | 3.2.2.1 | Magazijnwerknemers maken | 0.5h | 2004-01-27 11:00 | 2004-01-27 11:30 | 205 | 246.72d | 0d |
| 212 | 5.4.2.2.3 | Opslaglocatiesjablonen maken | 0.5h | 2004-01-27 11:30 | 2004-01-27 12:00 | 211 | 246.72d | 0d |
| 213 | 5.4.2.2.4 | Opslaglocatiesoorten maken | 0.5h | 2004-01-27 13:00 | 2004-01-27 13:30 | 212 | 246.72d | 0d |
| 214 | 5.4.2.2.5 | Magazijnklassen maken | 0.5h | 2004-01-27 13:30 | 2004-01-27 14:00 | 213 | 246.72d | 0d |
| 215 | 3.2.2.2 | Opslaglocaties maken met een opslaglocatie-aanmaakvoorstel | 0.5h | 2004-01-27 14:00 | 2004-01-27 14:30 | 214 | 246.72d | 0d |
| 216 | 3.2.2.3 | Opslaglocatie-inhoud maken | 0.5h | 2004-01-27 14:30 | 2004-01-27 15:00 | 215 | 246.72d | 0d |
| 217 | 3.2.2.4 | Magazijninstellingen - standaardopslaglocaties | 0.5h | 2004-01-27 15:00 | 2004-01-27 15:30 | 216 | 246.72d | 0d |
| 218 | 3.2.2.5 | Speciaal materieel maken | 0.5h | 2004-01-27 15:30 | 2004-01-27 16:00 | 217 | 246.72d | 0d |
| 219 | 3.2.2.6 | Magazijndagboeksjablonen | 0.5h | 2004-01-27 16:00 | 2004-01-27 16:30 | 218 | 246.72d | 0d |
| 220 | 3.2.2.7 | Magazijnvoorstelsjabloon maken | 0.5h | 2004-01-27 16:30 | 2004-01-27 17:00 | 219 | 246.72d | 0d |
| 221 | 3.2.2.8 | Opslagsjabloon maken | 0.5h | 2004-01-28 08:00 | 2004-01-28 08:30 | 220 | 246.72d | 0d |
| 222 | 5.4.2.3 | **Dag 3 integratieproblemen** | 5d? | 2004-01-28 08:30 | 2004-02-04 08:30 | 221 | 246.72d |  |
| 223 | 5.4.2.3.1 | Cross-docken | 8h? | 2004-01-28 08:30 | 2004-01-29 08:30 |  | 246.72d | 0d |
| 224 | 5.4.2.3.2 | Interne magazijnopslag - productie | 8h? | 2004-01-29 08:30 | 2004-01-30 08:30 | 223 | 246.72d | 0d |
| 225 | 5.4.2.3.3 | Interne magazijnpick - productie | 8h? | 2004-01-30 08:30 | 2004-02-02 08:30 | 224 | 246.72d | 0d |
| 226 | 5.4.2.3.4 | Magazijninventarisatie | 8h? | 2004-02-02 08:30 | 2004-02-03 08:30 | 225 | 246.72d | 0d |
| 227 | 5.4.2.3.5 | Magazijnvoorraadherwaardering in de artikelposten | 8h? | 2004-02-03 08:30 | 2004-02-04 08:30 | 226 | 246.72d | 0d |

Notes:
- 206: Situatie vooraf: / Het personeel van de klant neemt deel aan de vergadering. / Actie: / De consultant of projectmanager leidt de kick off-vergadering waarin het volgende aan de orde komt: / - Doel van het project / - Verwachtingen ten aanzien van het resultaat / - Verwachte werklast voor iedere werknemer / - Basisregels voor het project * / Situatie achteraf: / Het personeel van de klant weet wat er te gebeuren staat, is klaar om aan het project te beginnen en weet hoe samen te werken met de consultant. / Taak voor de manager van het personeel van de klant: / Zorgen dat alle werknemers gemotiveerd zijn om aan het project te werken / * Basisregels kunnen zijn: / - Werkuren (begin/einde/lunch) / - Verwachte voorbereiding / - Factureringsregels (uren/vervoer/hotels) (in het bijzonder voor projecten met een vaste prijs) / - De afhandeling van afwijkingen van het project / - Wie neemt de beslissing over te factureren uren die buiten het bereik van het project vallen? / - Enzovoort
- 207: WMS-instellingen / Verklaren: / Opslaglocatiesoorten / Een opslaglocatie is de kleinste containereenheid in het WMS-magazijn. Het is mogelijk om de activiteiten die zijn toegestaan voor een opslaglocatie, te beperken door aan de opslaglocatie een opslaglocatiesoort toe te wijzen. / Ontvangen / Opslaan / Picken / Verzenden / Ontvangen en picken / Opslaan en picken / Ontvangen en verzenden / Geen / Magazijnklassen / Werken met magazijnklassen en de standaardopslaglocatie voor ontvangen/verzenden / Maximumaantallen instellen voor opslaglocaties / Een maximumaantal instellen voor een specifiek artikel dat op een afzonderlijke opslaglocatie kan worden opgeslagen
- 208: Bespreek op basis van het bedrijfsproces van de klant de volgende onderwerpen: / Uit-/inslag order voor order / Uit-/inslag goederen meerdere orders / Cross-docken / Integratie / Productie / Voorraad
- 210: Situatie vooraf: / De vragenlijst over het magazijn is door de klant ingevuld. Alle gegevens voor de magazijnbeheerinstellingen zijn daarom aangemaakt in Excel. / Actie: / Open het implementatiehulpprogramma, kies Vragenlijstgegevens. Voer het pad en de naam in van het bestand dat de vragenlijst bevat, en kies Importeren. / Situatie achteraf: / De gegevens voor magazijnbeheer zijn in de Navision-database geïmporteerd. / Taken voor het personeel van de klant: / Controleren of de geïmporteerde gegevens juist zijn

| ID | WBS | Task | Duration | Start | Finish | Predecessors | Total slack | Free slack |
| --- | --- | --- | --- | --- | --- | --- | --- | --- |
| 228 | 3.2.3 | **Dag 4+5 magazijnbeheerprocedures** | 5.28d? | 2004-02-04 08:30 | 2004-02-11 10:45 |  | 246.72d |  |
| 229 | 5.4.2.4.1 | **Inkomende stroom** | 2d? | 2004-02-04 08:30 | 2004-02-06 08:30 | 227 | 246.72d |  |
| 230 | 5.4.2.4.1.1 | Inkomend magazijnverzoek | 8h? | 2004-02-04 08:30 | 2004-02-05 08:30 |  | 251d |  |
| 231 | 5.4.2.4.1.2 | Magazijnontvangst (3 stuks) | 8h? | 2004-02-04 08:30 | 2004-02-05 08:30 |  | 250d | 0d |
| 232 | 5.4.2.4.1.3 | Ontvangstboeking | 8h? | 2004-02-05 08:30 | 2004-02-06 08:30 | 231 | 250d |  |
| 233 | 5.4.2.4.1.4 | Magazijnopslagvoorstel | 8h? | 2004-02-04 08:30 | 2004-02-05 08:30 |  | 246.72d | 0d |
| 234 | 5.4.2.4.1.5 | Magazijnopslag | 8h? | 2004-02-05 08:30 | 2004-02-06 08:30 | 233 | 246.72d | 0d |
| 235 | 5.4.2.4.2 | **Interne verplaatsingen** | 0.09d | 2004-02-06 08:30 | 2004-02-06 09:15 |  | 246.72d |  |
| 236 | 3.2.3.3 | Verplaatsingsvoorstel | 0.5h | 2004-02-06 08:30 | 2004-02-06 09:00 | 234 | 246.72d | 0d |
| 237 | 3.2.3.4 | Magazijnverplaatsing | 0.25h | 2004-02-06 09:00 | 2004-02-06 09:15 | 236 | 246.72d | 0d |
| 238 | 5.4.2.4.3 | **Uitgaande stroom** | 3.19d? | 2004-02-06 09:15 | 2004-02-11 10:45 |  | 246.72d |  |
| 239 | 5.4.2.4.3.1 | Uitgaand magazijnverzoek | 8h? | 2004-02-06 09:15 | 2004-02-09 09:15 | 237 | 246.72d | 0d |
| 240 | 3.2.3.5 | Magazijnverzending | 0.25h | 2004-02-09 09:15 | 2004-02-09 09:30 | 239 | 246.72d | 0d |
| 241 | 5.4.2.4.3.3 | Verzenddocument afdrukken | 8h? | 2004-02-09 09:30 | 2004-02-10 09:30 | 240 | 246.72d | 0d |
| 242 | 5.4.2.4.3.4 | Pickproces plannen | 8h? | 2004-02-10 09:30 | 2004-02-11 09:30 | 241 | 246.72d | 0d |
| 243 | 3.2.3.6 | Magazijnpick | 0.25h | 2004-02-11 09:30 | 2004-02-11 09:45 | 242 | 246.72d | 0d |
| 244 | 3.2.3.20 | Magazijnpickvoorstel | 0.5h | 2004-02-11 09:45 | 2004-02-11 10:15 | 243 | 246.72d | 0d |
| 245 | 3.2.3.21 | Magazijnpick | 0.25h | 2004-02-11 10:15 | 2004-02-11 10:30 | 244 | 246.72d | 0d |
| 246 | 3.2.3.22 | Magazijnverzending | 0.25h | 2004-02-11 10:30 | 2004-02-11 10:45 | 245 | 246.72d |  |
| 247 | 6 | **Bewerkingsfase** | 2d? | 2004-01-13 08:30 | 2004-01-15 08:30 |  | 266d |  |
| 248 | 6.1 | **2+5+2-concept** | 1d? | 2004-01-13 08:30 | 2004-01-14 08:30 |  | 267d |  |
| 249 | 6.1.1 | **2 dagen postmortem** | 1d? | 2004-01-13 08:30 | 2004-01-14 08:30 |  | 267d |  |
| 250 | 6.1.1.1 | Dag 1 - evaluatie | 8h? | 2004-01-13 08:30 | 2004-01-14 08:30 |  | 267d |  |
| 251 | 6.1.1.2 | Dag 2 - follow-up | 8h? | 2004-01-13 08:30 | 2004-01-14 08:30 |  | 267d |  |

| ID | WBS | Task | Duration | Start | Finish | Total slack |
| --- | --- | --- | --- | --- | --- | --- |
| 252 | 6.2 | **Uitbreiding** | 2d? | 2004-01-13 08:30 | 2004-01-15 08:30 | 266d |
| 253 | 6.2.1 | **2 dagen uitgebreide postmortem** | 2d? | 2004-01-13 08:30 | 2004-01-15 08:30 | 266d |
| 254 | 6.2.1.1 | Dag 1 - uitgebreide evaluatie | 16h | 2004-01-13 08:30 | 2004-01-15 08:30 | 266d |
| 255 | 6.2.1.2 | Dag 2 - uitgebreide follow-up | 8h? | 2004-01-13 08:30 | 2004-01-14 08:30 | 267d |
