# Template version 0.9

Schedule from MS Project, 2004-01-13 to 2005-01-21.
Microsoft Corporation

## Calendars

- Standard: Mon-Fri 08:00-12:00, 13:00-17:00; Sat-Sun off. Exceptions (off unless hours are given): 2004-05-27 08:00-12:00, 13:00-17:00.

## Schedule

| ID | WBS | Task | Type | Duration | Start | Finish | Predecessors | Total slack | Free slack | Constraint |
| --- | --- | --- | --- | --- | --- | --- | --- | --- | --- | --- |
| 1 | 1 | Navision Implementation Process |  | 14d | 2005-01-03 08:30 | 2005-01-21 08:30 |  | 0d |  | start no earlier than 2005-01-03 08:30 |
| 2 | 2 | **Pre-Analysis Phase** |  | 8d? | 2004-01-13 08:30 | 2004-01-23 08:30 |  | 251.97d |  |  |
| 3 | 2.1 | **Brief and Plan** |  | 2d? | 2004-01-13 08:30 | 2004-01-15 08:30 |  | 251.97d |  |  |
| 4 | 2.1.1 | Opportunity Briefing |  | 8h? | 2004-01-13 08:30 | 2004-01-14 08:30 |  | 251.47d | 0d |  |
| 5 | 2.1.2 | Pre-Analysis Briefing |  | 8h? | 2004-01-13 08:30 | 2004-01-14 08:30 |  | 251.47d | 0d |  |
| 6 | 2.1.3 | Pre-Analysis Plan |  | 8h? | 2004-01-14 08:30 | 2004-01-15 08:30 | 5, 4 | 251.47d | 0d |  |
| 7 | 2.2 | **High Level Gap/Fit Analysis** |  | 3d? | 2004-01-15 08:30 | 2004-01-20 08:30 |  | 251.97d |  |  |
| 8 | 2.2.1 | Identification of all Business Process |  | 8h? | 2004-01-15 08:30 | 2004-01-16 08:30 | 6 | 251.47d | 0d |  |
| 9 | 2.2.2 | High Level Gap/Fit Analysis |  | 8h? | 2004-01-16 08:30 | 2004-01-19 08:30 | 8 | 251.47d | 0d |  |
| 10 | 2.2.3 | Consider 3rd Party Solutions |  | 8h? | 2004-01-19 08:30 | 2004-01-20 08:30 | 9, 8 | 251.47d | 0d |  |
| 11 | 2.3 | **Scoping** |  | 4d? | 2004-01-15 08:30 | 2004-01-21 08:30 |  | 251.97d |  |  |
| 12 | 2.3.1 | Business Scoping Process |  | 8h? | 2004-01-20 08:30 | 2004-01-21 08:30 | 10, 9 | 251.47d | 0d |  |
| 13 | 2.3.2 | Preliminary Infrastructure Analysis |  | 8h? | 2004-01-15 08:30 | 2004-01-16 08:30 | 6 | 254.47d | 3d |  |
| 14 | 2.4 | **Project Plan & Proposal** |  | 2d? | 2004-01-21 08:30 | 2004-01-23 08:30 |  | 251.97d |  |  |
| 15 | 2.4.1 | Determine Project Type | milestone | 8h? | 2004-01-21 08:30 | 2004-01-22 08:30 | 13, 12 | 261d |  |  |
| 16 | 2.4.2 | Project Planning |  | 8h? | 2004-01-21 08:30 | 2004-01-22 08:30 | 12, 13 | 251.47d | 0d |  |
| 17 | 2.4.3 | Proposal |  | 8h? | 2004-01-22 08:30 | 2004-01-23 08:30 | 16, 12, 13 | 251.47d | 0d |  |
| 18 | 3 | Customer Acceptance | milestone | 8h? | 2004-01-13 08:30 | 2004-01-14 08:30 |  | 267d |  |  |
| 19 | 4 | **Analysis Phase** |  | 8d | 2004-01-23 08:30 | 2004-02-04 08:30 |  | 251.97d |  |  |
| 20 | 4.1 | **15 Days- Detailed Analysis** |  | 8d | 2004-01-23 08:30 | 2004-02-04 08:30 | 17 | 251.97d |  |  |
| 21 | 4.1.1 | Update Pre-Analysis Plan |  | 0.5d | 2004-01-23 08:30 | 2004-01-23 13:30 | 17 | 251.97d | 0d |  |
| 22 | 4.1.2 | Create Sandbox environment |  | 1d | 2004-01-23 13:30 | 2004-01-26 13:30 | 21 | 258.5d |  |  |
| 23 | 4.1.3 | Detailed Analysis |  | 5d | 2004-01-23 13:30 | 2004-01-30 13:30 | 21 | 254.5d |  |  |
| 24 | 4.1.4 | Detailed Gap/Fit Analysis |  | 7.5d | 2004-01-23 13:30 | 2004-02-04 08:30 | 21 | 252d |  |  |
| 25 | 4.1.5 | Detailed Gap/Fit Scoping |  | 1d | 2004-01-23 13:30 | 2004-01-26 13:30 | 21 | 251.97d | 0d |  |

| ID | WBS | Task | Type | Duration | Start | Finish | Predecessors | Total slack | Free slack |
| --- | --- | --- | --- | --- | --- | --- | --- | --- | --- |
| 26 | 5 | **Deploy Phase** |  | 21.28d? | 2004-01-13 08:30 | 2004-02-11 10:45 |  | 246.72d |  |
| 27 | 2 | **2+5+2 Concept (phase One)** |  | 6.53d | 2004-01-26 13:30 | 2004-02-04 08:45 | 17, 25 | 251.97d |  |
| 28 | 2.1 | **2 Days -Preparation** |  | 1.88d | 2004-01-26 13:30 | 2004-01-28 11:30 |  | 251.97d | 0d |
| 29 | 2.1.1 | Day 1 Knowledge transfer |  | 1d | 2004-01-26 13:30 | 2004-01-27 13:30 |  | 251.97d | 0d |
| 30 | 2.1.2 | **Day 2 Meeting the customer** |  | 0.88d | 2004-01-27 13:30 | 2004-01-28 11:30 | 29 | 251.97d | 0d |
| 31 | 2.1.2.1 | Introduction meeting |  | 3h | 2004-01-27 13:30 | 2004-01-27 16:30 |  | 251.97d | 0d |
| 32 | 2.1.2.2 | Installation of client + database (live or sandbox) |  | 2h | 2004-01-27 16:30 | 2004-01-28 09:30 | 31 | 251.97d | 0d |
| 33 | 2.1.2.3 | Sign off on the questionnaires |  | 1h | 2004-01-28 09:30 | 2004-01-28 10:30 | 32, 31 | 251.97d | 0d |
| 34 | 2.1.2.4 | Database - Company Setup |  | 1h | 2004-01-28 10:30 | 2004-01-28 11:30 | 33 | 251.97d |  |
| 35 | 2.1.2.5 | Summary |  | 1h | 2004-01-28 10:30 | 2004-01-28 11:30 | 33 | 251.97d |  |
| 36 | 2.2 | **5 Days - Implementation** |  | 4.66d | 2004-01-28 11:30 | 2004-02-04 08:45 | 28 | 251.97d |  |
| 37 | 2.2.1 | **Day 1 - Kick Off** |  | 1d | 2004-01-28 11:30 | 2004-01-29 11:30 | 30 | 251.97d | 0d |
| 38 | 2.2.1.1 | Kick off meeting |  | 1h | 2004-01-28 11:30 | 2004-01-28 13:30 |  | 252.84d |  |
| 39 | 2.2.1.2 | Setup Users |  | 2h | 2004-01-28 11:30 | 2004-01-28 14:30 |  | 251.97d | 0d |
| 40 | 2.2.1.3 | Introduction to the Master Data Migration concept |  | 1h | 2004-01-28 14:30 | 2004-01-28 15:30 | 39 | 251.97d | 0d |
| 41 | 5.1.2.1.4 | Introduction to the Master Template Concept |  | 1h | 2004-01-28 15:30 | 2004-01-28 16:30 | 40 | 251.97d | 0d |
| 42 | 2.2.1.4 | Determine deadlines and responsible for Master Data entry |  | 0.5h | 2004-01-28 16:30 | 2004-01-28 17:00 | 41 | 251.97d | 0d |
| 43 | 2.2.1.5 | Look and feel of Print outs |  | 1h | 2004-01-29 08:00 | 2004-01-29 09:00 | 42 | 251.97d | 0d |
| 44 | 2.2.1.6 | Planning of user Process- training (precondition for following days) |  | 2h | 2004-01-29 09:00 | 2004-01-29 11:00 | 43 | 251.97d | 0d |
| 45 | 2.2.1.7 | Prepare day 2 |  | 0.5h | 2004-01-29 11:00 | 2004-01-29 11:30 | 44 | 251.97d |  |
| 46 | 2.2.2 | **Day 2 - General Ledger** |  | 0.94d | 2004-01-29 11:30 | 2004-01-30 11:00 | 37 | 251.97d | 0d |
| 47 | 2.2.2.1 | Process -Training "Basic General Ledger" | milestone | 0h | 2004-01-29 11:30 | 2004-01-29 11:30 |  | 252.91d |  |
| 48 | 2.2.2.2 | General talk about chart of accounts and creation of business posting groups. |  | 1h | 2004-01-29 11:30 | 2004-01-29 13:30 |  | 251.97d | 0d |
| 49 | 5.1.2.2.3 | Validate Master Date template |  | 1h | 2004-01-29 13:30 | 2004-01-29 14:30 | 48 | 252.06d | 0d |
| 50 | 2.2.2.3 | Import Chart of accounts |  | 0.5h | 2004-01-29 14:30 | 2004-01-29 15:00 | 49 | 252.06d | 0.09d |
| 51 | 2.2.2.5 | Decide Posting Groups and Posting setup |  | 1.25h | 2004-01-29 13:30 | 2004-01-29 14:45 | 48 | 251.97d | 0d |
| 52 | 2.2.2.6 | Decide VAT Posting groups and VAT posting setup |  | 1h | 2004-01-29 14:45 | 2004-01-29 15:45 | 51 | 251.97d | 0d |
| 53 | 2.2.2.7 | Update of Chart of accounts |  | 0.5h | 2004-01-29 15:45 | 2004-01-29 16:15 | 52, 51, 50 | 251.97d | 0d |
| 54 | 2.2.2.8 | Update Currency Code table |  | 0.25h | 2004-01-29 16:15 | 2004-01-29 16:30 | 53 | 251.97d | 0d |
| 55 | 2.2.2.9 | Create bank Accounts and Bank Account posting groups |  | 0.5h | 2004-01-29 16:30 | 2004-01-29 17:00 | 54, 51 | 251.97d | 0d |
| 56 | 2.2.2.10 | Practice: G/L Posting |  | 1h | 2004-01-30 08:00 | 2004-01-30 09:00 | 55 | 251.97d | 0d |
| 57 | 2.2.2.11 | Practice: Budget |  | 1h | 2004-01-30 09:00 | 2004-01-30 10:00 | 56 | 251.97d | 0d |
| 58 | 2.2.2.12 | Practice: Account Schedules |  | 1h | 2004-01-30 10:00 | 2004-01-30 11:00 | 57 | 251.97d |  |
| 59 | 2.2.2.13 | Prepare Day 3 |  | 1h | 2004-01-29 11:30 | 2004-01-29 13:30 |  | 252.78d |  |

Notes:
- 27: This 2+5+2 Concept is a Project Template for any Phase 1 Navision Implementation Project. / It is not a complete project plan, but a template for you to develop further upon. / When You plan new projects, use this project plan as you starting point and expand it with the issues you know the customer also need. / Follow the structure and be specific in describing how tasks are to be processed. / With some experience You or the MBS Partner You work for can build default Project Templates for you typical customer.
- 28: Precondition: / Action: / Post condition: / Tasks for Customer resource:
- 29: Transfer the knowledge obtained in the sales process of the sales manager to the implementation consultant or team, in order to avoid asking the same questions to the customer using the questionnaire. / Prepare a proposal for a schedule and plan for which resources to be used. / Prepare possible additional questions.
- 31: Precondition: / Knowledge transfer from Sales person to consultant completed. / Installation CD and Customer License is available at customer sight. / Action: / Opening meeting: / - Who is who / - Customer makes a short presentation of the company to the consultant's) / - Customer expectations from the project / - Consultant presents the overall project and implementation tasks / - Consultant presents the expectations to the customer tasks / - Consultant presents the tasks for the day / - Consultant introduces customer to Questionnaire(s) / ·Company Information / ·General Ledger / ·Sales & Receivables / ·Purchase & Payables / ·Inventory / ·Relationship Management / ·Fixed Assets / - Consultant introduces customer to Navision / - Agreement to the project plan / - Agreement on training classes / Post condition: / Customer is aware of the next steps and has an overview of the process. / Consultant has a brief knowledge of the customer / Tasks for Customer resource: / Fill in Questionnaire(s).
- 32: Precondition: / Customer has prepared a PC/Server that has disk space to contain Navision software and the database / Minimum windows 98 and minimum 500 Mb free space / Action: / Installation of Navision Server / Installation of Navision Client / Import of CRONUS Demo database / Import of customer license / Create Customer Company and select Company Type / Post condition: / Database ready in a networking environment / Tasks for Customer resource: / Distribute clients to other PC's
- 33: Precondition: / Questionnaire files available. / Customer has filled out questionnaire from Introduction meeting / Action: / Make a walkthrough of the questionnaire(s). / Sign off on the questionnaire. / Save questionnaire to disk. / Post condition: / Questionnaire is ready for import. / Tasks for Customer resource:
- 34: Precondition: / Navision Client Server environment installed (Sandbox). / Company created / Customer has filled out questionnaire from Introduction meeting / Action: / Import the Questionnaire(s) / Validate the Questionnaire(s) / Apply Answers to the Questionnaire(s) / Post condition: / Customer database is ready for implementation. / Tasks for Customer resource:
- 35: Precondition: / All tasks in "1st. meeting with customer" completed (except this) / Action: / Summary of the customer tasks until next step in project. / Agenda for next meeting / Agree on next meeting date / Post condition:/ Customer aware of next step / Tasks for Customer resource:
- 38: Precondition: / Customer resources attend meeting / Action: / Consultant / Project manager performs kick-off meeting containing: / - Purpose of project / - Expectations for the Result / - Expectations for workload for each employee / - "Basic rules" for project * / Post condition:/ Customer resource is aware and ready for the project and know how to cooperate with consultant. / Task for Customer Manager / That all employees are motivated to do the project. / * Basic rules could be: / - Working Hours (start/end/lunch) / - Expected preparation / - Billing rules (Hours/Transportation/Hotels) (Especially for fixed price projects) / - Handling of project deviations / - Who is decision maker on Billable hours outside Project Scope? / - etc.
- 39: Precondition: / None / Action: / Brief training of customer resource in Users, Login, Roles and Permissions / Customer resource is supplied with Navision documentation of the subject. / Post condition: / Customer resource has knowledge and training material. / Tasks for Customer resource: / Create the users and set up roles and permissions.
- 40: Precondition: / Spreadsheets are created in Topic 9 (2.nd. preparation day)/ Customer resources (Sales, Purchase, GL, Inventory) are participating. / Action: / Show the spreadsheets and explain how data should be created in the spreadsheets. / Decide for data to be migrated. / Common guidelines for filling in data in the spreadsheets:/ - Method 1: Fill in data in exported sheet (18 for customer) / - Method 2: Fill in data in sheet 1and make field references in the exported sheet. / - Be aware of Master Data Templates for simplifying the spreadsheets. / - DO NOT re-arrange the columns in the exported sheet. / - Length of data in field MUST not exceed field properties. / - The customer is responsible for this before import. / - How to get F1 - help for fields. (Look in the database, find field maybe Ctrl F8, Value, F1.) Maybe create and print out a spread sheet with all F1 help included. / - Examples of how to fill out. / - Guidance in how to format the columns, so they match the Field options. This will prevent the customer resource to enter data that can not be imported. / Post condition:/ Customer Resource ready to create Data Sheets / Tasks for Customer resource: / Create Master Data Migration Sheets.
- 41: Precondition: / Spreadsheets are created in Topic 9 (2.nd. preparation day)/ Customer resources (Sales, Purchase, GL, Inventory) are participating. / Action: / Explain the functionality of the Master Data Templates. / Validate existing Master Data Templates by / - altering to fit customer / - create necessary additional Master Data Templates / Decide on possible other Tables where Master Data Templates can apply. / Post condition:/ Necessary Master Data Templates are created. / Tasks for Customer resource: / Instruct users in using Master Data Templates together with Master Data Migration.
- 42: Precondition: / Super Users has received education in Master Data Spreadsheets. / Action: / - Determine responsible customer resource for each spreadsheet (customer, Vendor, Inventory, GL, Contacts) / - Agree on deadlines for spreadsheets completion. / Post condition:/ Customer resource aware of tasks and deadlines / Tasks for Customer resource: / Fill in the spreadsheets.
- 43: Precondition: / Customer resources (Sales, Purchase, GL, Inventory) are participating. / Action: / Basic training in how to select and print a report. / Walk through of standard reports (print outs) from Navision for each of the areas in the license. / All reports are printed and handed to the customer resource. / NOTICE! Changes to reports are not included in the 2+5+2 project timeframe. / Post condition:/ Customer resources aware of Navision standard reporting facilities. / Tasks for Customer resource:
- 44: Precondition: / Customer resource has decision making authority. / MBS Partner perform or have access to Navision User training Center (none specific) / Action: / Planning meeting with customer decision maker regarding training classes. / Mandatory Training classes: / - General Ledger Basic / - Sales & Receivables Basic / - Purchase & payables Basic / - Inventory Basic / Optional Training classes (for extensions to Phase one) / - Relationship Management Basic / - Manufacturing / - WareHouse Management / - Any extended class / Post condition:/ Dates and names defined for each training class. / Tasks for Customer resource: / Make sure participants have knowledge of date and address. / Make sure participants actually participate
- 45: Precondition: / Day 1 completed / Action: / Determine and agree on date for Day 2 with customer project responsible / Preparation of Day 2 / Post condition: / Tasks for Customer resource:
- 47: Training as defined in day 1
- 48: Precondition: / Day 2 completed / Action: / Basic introduction to the functionality of G/L and Chart of Accounts in Navision. / Follow up on basic training process. / Guidance in creating Chart of Accounts / Post condition:/ Customer resource ready for importing/creating Chart of Accounts / Tasks for Customer resource:
- 49: Precondition: / Sandbox environment available. / Action: / Decide if a Master Data Template for G/L Accounts ca be created. / If so - create it / Post condition: / Tasks for Customer resource:
- 50: Precondition: / Master Data Excel Spread sheet is filled out by customer. / Action: / Open the Migration Overview and import the Spreadsheet. / Solve errors shown in the Migration Matrix. / Select Master Data Template. / Apply error free data / Tip: Group Master Data according to Master Data Templates and import template by template. / This will drastically reduce the amount of data to be imported from spreadsheets. / Post condition:/ Items are imported to the Navision Database. / Tasks for Customer resource: / Validate that Imported data are correct
- 51: Precondition: / Client Resource has competence in G/L / Customers / Vendors / Inventory. / Action: / - Refresh knowledge of consequence of Posting Groups. / - Discuss company Posting needs. / - According to the Chart of Account layout enter the posting groups needed. / - Create the posting setup necessary. / Post condition:/ A client-written decision of posting groups at Company / Tasks for Customer resource: / - Create all needed posting groups / - Create the posting setup
- 52: Precondition: / Customer Resource has competence in G/L / national VAT rules. / Action: / - Refresh knowledge of consequence of VAT Posting Groups. / - Discuss company VAT Posting needs. / - According to the national VAT rules enter the posting groups needed. / - Create the posting setup necessary. / Post condition: / A Customer resource written decision of VAT posting groups at Company
- 53: Precondition: / Customer Resource has competence in G/L / Customers / Vendors / Inventory. / Action: / - Discuss Navision needs. / - Enter (update) the fields Gen. Bus. Posting group, Gen. prod. Posting group, gen. posting type, VAT bus. Posting group, VAT prod. Posting group wherever needed. / Tasks for Customer resource: / - Updating the entire Chart of accounts.
- 54: Precondition: / Customer Resource has competence in G/L / Customers / Vendors / Inventory. / Action: / - Enter (update) the fields concerning realized- and unrealized gains and losses. / Tasks for customer resource: / - Updating the Currency code table.
- 55: Precondition: / Customer Resource has competence in G/L / Customers / Vendors / Inventory. / Action: / - Enter the Bank Accounts needed for the company. / Tasks for customer resource: / - Entering further bank accounts if needed.
- 56: Precondition: / Customer Resource has competence in G/L / Customers / Vendors / Inventory. / Action: / - Entering data in the G/L journals. / - Test for correct VAT calculation. / - Printing Test report. / - Posting. / - Control of correct G/L entries and correct VAT postings. / - G/L reports: Balance Detail trial balance. / - Filtering in Chart of accounts. / - Navigate. / Customer resource should do the typing under consultant supervision. / Post condition:/ Customer resource should gather basic knowledge of daily used functions. / Tasks for Customer resource: / Practice, practice, practice…
- 57: Precondition: / Customer Resource has competence in G/L / Customers / Vendors / Inventory. / Action: / - Entering data in the Budget Schemes. / - G/L reports: Balance/Budget. / - Filtering in Budget Schemes. / - Export to Excel Import from Excel. / Customer resource should do the typing under consultant supervision. / Post condition:/ Customer resource should gather basic knowledge of daily used budgeting. / Tasks for Customer resource: / Practice, practice, practice…
- 58: Precondition: / Customer Resource has competence in G/L / Customers / Vendors / Inventory. / Action: / Entering data (template) in the account schedule. Set up column layout. / Export to Excel. Print Acc. Schedule. / Customer resource should do the typing under consultant supervision. / Post condition:/ Customer resource should gather basic knowledge of daily used functions. / Tasks for Customer resource: / Practice, practice, practice…
- 59: Precondition: / Day 2 completed / Action: / Determine and agree on date for Day 3 with customer project responsible / Preparation of Day 3 / Post condition: / Tasks for Customer resource:

| ID | WBS | Task | Type | Duration | Start | Finish | Predecessors | Total slack | Free slack |
| --- | --- | --- | --- | --- | --- | --- | --- | --- | --- |
| 60 | 2.2.3 | **Day 3 Customer /Vendor** |  | 0.88d | 2004-01-30 11:00 | 2004-02-02 10:00 | 46 | 251.97d | 0d |
| 61 | 2.2.3.1 | Process -Training "Basic Sales & Receivables" | milestone | 0h | 2004-01-30 11:00 | 2004-01-30 11:00 |  | 252.84d |  |
| 62 | 2.2.3.2 | Process - Training "Basic Purchase & Payables" | milestone | 0h | 2004-01-30 11:00 | 2004-01-30 11:00 |  | 252.84d |  |
| 63 | 5.1.2.3.3 | Validate Master Data templates - Customer |  | 1h | 2004-01-30 11:00 | 2004-01-30 12:00 |  | 252.72d |  |
| 64 | 5.1.2.3.4 | Validate Master Data Templates - Vendor |  | 1h | 2004-01-30 11:00 | 2004-01-30 12:00 |  | 252.72d |  |
| 65 | 2.2.3.3 | Import Master Data |  | 0.25h | 2004-01-30 11:00 | 2004-01-30 11:15 |  | 251.97d | 0d |
| 66 | 2.2.3.5 | **Customer / Sales Information** |  | 0.5d | 2004-01-30 11:15 | 2004-01-30 16:15 | 65 | 251.97d |  |
| 67 | 2.2.3.5.1 | Setup of Posting groups, sales |  | 0.5h | 2004-01-30 11:15 | 2004-01-30 11:45 |  | 251.97d | 0d |
| 68 | 2.2.3.5.2 | Setup of Sales parameters |  | 0.5h | 2004-01-30 11:45 | 2004-01-30 13:15 | 67 | 251.97d | 0d |
| 69 | 2.2.3.5.3 | Going through the fields in the customer card |  | 0.5h | 2004-01-30 13:15 | 2004-01-30 13:45 | 68 | 251.97d | 0d |
| 70 | 2.2.3.5.4 | Salesperson codes and commissions |  | 0.25h | 2004-01-30 13:45 | 2004-01-30 14:00 | 69 | 251.97d | 0d |
| 71 | 2.2.3.5.5 | Invoice discount |  | 0.25h | 2004-01-30 14:00 | 2004-01-30 14:15 | 70 | 251.97d | 0d |
| 72 | 2.2.3.5.6 | Price groups |  | 0.5h | 2004-01-30 14:15 | 2004-01-30 14:45 | 71 | 251.97d | 0d |
| 73 | 2.2.3.5.7 | Customer discount |  | 0.5h | 2004-01-30 14:45 | 2004-01-30 15:15 | 72 | 251.97d | 0d |
| 74 | 2.2.3.5.8 | Payment Terms |  | 0.25h | 2004-01-30 15:15 | 2004-01-30 15:30 | 73 | 251.97d | 0d |
| 75 | 2.2.3.5.9 | Fin. Charge Terms |  | 0.25h | 2004-01-30 15:30 | 2004-01-30 15:45 | 74 | 251.97d | 0d |
| 76 | 2.2.3.5.10 | Shipment codes and agents |  | 0.25h | 2004-01-30 15:45 | 2004-01-30 16:00 | 75 | 251.97d | 0d |
| 77 | 2.2.3.5.11 | Ship-to addresses |  | 0.25h | 2004-01-30 16:00 | 2004-01-30 16:15 | 76 | 251.97d | 0d |
| 78 | 2.2.3.6 | **Vendor / Purchase Information** |  | 0.34d | 2004-01-30 16:15 | 2004-02-02 10:00 | 77 | 251.97d |  |
| 79 | 2.2.3.6.1 | Setup of Posting groups, purchase |  | 0.5h | 2004-01-30 16:15 | 2004-01-30 16:45 |  | 251.97d | 0d |
| 80 | 2.2.3.6.2 | Setup of Purchase parameters |  | 0.25h | 2004-01-30 16:45 | 2004-01-30 17:00 | 79 | 251.97d | 0d |
| 81 | 2.2.3.6.3 | Going through the fields in the vendor card |  | 0.25h | 2004-02-02 08:00 | 2004-02-02 08:15 | 80 | 251.97d | 0d |
| 82 | 2.2.3.6.4 | Purchaser codes |  | 0.25h | 2004-02-02 08:15 | 2004-02-02 08:30 | 81 | 251.97d | 0d |
| 83 | 2.2.3.6.5 | Invoice discount |  | 0.25h | 2004-02-02 08:30 | 2004-02-02 08:45 | 82 | 251.97d | 0d |
| 84 | 2.2.3.6.6 | Order addresses |  | 0.25h | 2004-02-02 08:45 | 2004-02-02 09:00 | 83 | 251.97d | 0d |
| 85 | 2.2.3.6.7 | Vendor Item Catalog |  | 0.25h | 2004-02-02 09:00 | 2004-02-02 09:15 | 84 | 251.97d | 0d |
| 86 | 2.2.3.6.8 | Purchase prices |  | 0.5h | 2004-02-02 09:15 | 2004-02-02 09:45 | 85 | 251.97d | 0d |
| 87 | 2.2.3.6.9 | Line discount |  | 0.25h | 2004-02-02 09:45 | 2004-02-02 10:00 | 86 | 251.97d |  |

Notes:
- 61: Training as defined in day 1
- 62: Training as defined in day 1
- 63: Precondition: / Spreadsheets are created in Topic 9 (2.nd. preparation day)/ Customer resources (Sales) are participating. / Action: / Explain the functionality of the Master Data Templates. / Validate existing Master Data Templates by / - altering to fit customer / - create necessary additional Master Data Templates / Decide on possible other Tables where Master Data Templates can apply. / Post condition:/ Necessary Master Data Templates are created. / Tasks for Customer resource: / Instruct users in using Master Data Templates together with Master Data Migration.
- 64: Precondition: / Spreadsheets are created in Topic 9 (2.nd. preparation day)/ Customer resources ( Purchase) are participating. / Action: / Explain the functionality of the Master Data Templates. / Validate existing Master Data Templates by / - altering to fit customer / - create necessary additional Master Data Templates / Decide on possible other Tables where Master Data Templates can apply. / Post condition:/ Necessary Master Data Templates are created. / Tasks for Customer resource: / Instruct users in using Master Data Templates together with Master Data Migration.
- 65: Precondition: / Master Data Excel Spread sheet is filled out by customer. / Action: / Open the Migration Overview and import the Spreadsheet. / Solve errors shown in the Migration Matrix. / Select Master Data Template. / Apply error free data / Tip: Group Master Data according to Master Data Templates and import template by template. / This will drastically reduce the amount of data to be imported from spreadsheets. / Post condition:/ Items are imported to the Navision Database. / Tasks for Customer resource: / Validate that Imported data are correct
- 67: Precondition: / Customer Resource has competence in GL/Customers/Vendors, Customer / Action: / - Refresh knowledge of consequence of Posting Groups / - Discuss company Posting needs / - Fill in the needed G/L Accounts in the Posting groups / Post condition:/ A written decision of posting groups at Company / Tasks for Customer resource: / - Create all needed posting groups / - Attach posting groups to customer card / (option is to do this in the Excel Spread sheet and then Re-import) / - Test correct posting on invoicing
- 68: Precondition: / Client Resource has competence in G/L / sales. / Action: / Choose and fill in the necessary parameters / Post condition:/ The sales system will function as requested. / Tasks for Customer resource:
- 69: Precondition: / Client Resource has competence in G/L / sales, and works with creating customer on a regular basis. / Action: / Taking one customer card and explaining all the fields. / Post condition: / Tasks for Customer resource:
- 70: Precondition: / Client Resource has competence in sales and commissions, e.g. how much commission should be calculated, and to which salespersons. / Action: / Creating the salespersons codes and attaching the needed commission rates. / Post condition:/ After posting invoices a report can be printed, showing the calculated commission for each salesperson. / Tasks for Customer resource:
- 71: Precondition: / Customer Resource has competence in sales and when and how much discount is granted to customers. / Action: / - Creating the invoice discount groups and filling in the discount rates. / - Checking the posting set-up for the account to post invoice discount / Post condition:/ The invoice discount is calculated and posted automatically when invoicing a customer. / Tasks for Customer resource:
- 72: Precondition: / Customer Resource has competence in how the price system works. E.g. how many different pricelists are used, what the prices are and so on. / Action: / The price groups are created and attached to the customer card. / Post condition:/ When a sales order is created, the system will automatically find the right price for the item. / Tasks for Customer resource:
- 73: Precondition: / Customer Resource has competence in sales and when and how much discount is granted to customers. / Action: / - Creating the customer discount groups and filling in the discount rates. / - Checking the posting set-up for the account to post line discount / Post condition:/ The line discount rate is calculated automatically and put on the sales line, when creating an order. / Tasks for Customer resource:
- 74: Precondition: / Customer Resource has competence in sales and knows which payment terms are used, if there is any payment discounts and where discount should be posted. / Action: / - Creating payment terms with date formulas and discount rates. / Post condition:/ When creating a customer document, the due date will automatically be calculated, as will possible payment discount, if granted. / Tasks for Customer resource:
- 75: Precondition: / Customer Resource has competence in sales and knows which Financial Charge terms are used, if any. / Action: / Creating data connected to charge terms, e.g. charge rate, account no. / Post condition:/ It will be possible to create Fin. Charge Memos, which can be posted and/or send to the customers / Tasks for Customer resource:
- 76: Precondition: / Customer Resource has competence in sales and knows which shipment agents and codes are used. / Action: / - Creating shipment codes / - Creating shipment-agents with Internet addresses / Post condition:/ When posting an invoice, the shipment description will be printed on the shipments and invoices, and the shipment agent code can be used for order tracking through the internet. / Tasks for Customer resource:
- 77: Precondition: / Customer Resource has competence in sales and knows if any of the customers has attached ship-to addresses. / Action: / Creating ship-to addresses / Post condition:/ Ship-to addresses can be used, manually or automatically, on the sales documents, to send the goods to another address than the customers own. / Tasks for Customer resource:
- 79: Precondition: / Customer Resource has competence in GL/Customers/Vendors, Vendor / Action: / - Refresh knowledge of consequence of Posting Groups / - Discuss company Posting needs / - Fill in the needed G/L Accounts in the Posting groups / Post condition:/ A written decision of posting groups at Company / Tasks for Customer resource: / - Create all needed posting groups / - Attach posting groups to vendor card / (option is to do this in the Excel Spread sheet and then Re-import) / - Test correct posting on invoicing
- 80: Precondition: / Customer Resource has competence in G/L / Purchase. / Action: / Choose and fill in the necessary parameters / Post condition:/ The purchase system will function as requested. / Tasks for Customer resource:
- 81: Precondition: / Customer Resource has competence in G/L / purchase, and works with creating vendors on a regular basis. / Action: / Taking one vendor card an explaining all the fields. / Post condition: / Tasks for Customer resource:
- 82: Precondition: / Customer Resource has competence in G/L / purchase. / Action: / Creating the purchaser codes. / Post condition: / Tasks for Customer resource:
- 83: Precondition: / Customer Resource has competence in purchase and when and how much discount is granted from vendors. / Action: / - Creating the invoice discount groups and filling in the discount rates. / - Checking the posting set-up for the account to post invoice discount / Post condition:/ The invoice discount is calculated and posted automatically when posting an invoice from a vendor. / Tasks for Customer resource:
- 84: Precondition: / Customer Resource has competence in purchase and knows if any of the vendors has attached order addresses. / Action: / Creating order addresses / Post condition:/ Order addresses can be used, manually or automatically, on the purchase documents, to order the goods from another address than the vendors own. / Tasks for Customer resource:
- 85: Precondition: / Customer Resource has competence in purchase. / Action: / The list of item numbers at the vendor is created. / Post condition:/ It will be possible to get a list of the vendors item number, compared to your own item numbers. Also on reports, you can program, so the vendors number will be used instead of your own (e.g. purchase quotes). / Tasks for Customer resource:
- 86: Precondition: / Customer Resource has competence in how the price system works. E.g. how what the prices are from each vendor, if any minimum quantity is demanded and so on. / Action: / The price groups are created on each vendor. / Post condition:/ When a purchase order is created, the system will automatically find the right price for the item. / Tasks for Customer resource:
- 87: Precondition: / Customer Resource has competence in purchase and when and how much discount is granted from vendors. / Action: / - Creating the discount with minimum quantity, starting date and so on. / - Checking the posting set-up for the account to post line discount / Post condition:/ The line discount rate is calculated automatically and put on the purchase line, when creating an order. / Tasks for Customer resource:

| ID | WBS | Task | Duration | Start | Finish | Predecessors | Total slack | Free slack |
| --- | --- | --- | --- | --- | --- | --- | --- | --- |
| 88 | 2.2.4 | **Day 4 - Inventory** | 0.97d | 2004-02-02 10:00 | 2004-02-03 09:45 | 60 | 251.97d | 0d |
| 89 | 2.2.4.1 | Process - Training "Basic Inventory" | 0.5h | 2004-02-02 10:00 | 2004-02-02 10:30 |  | 252.88d |  |
| 90 | 2.2.4.2 | Create Manufacturer codes | 0.25h | 2004-02-02 10:00 | 2004-02-02 10:15 |  | 251.97d | 0d |
| 91 | 2.2.4.3 | Define Item category codes | 0.25h | 2004-02-02 10:15 | 2004-02-02 10:30 | 90 | 251.97d | 0d |
| 92 | 2.2.4.4 | Define Product groups | 0.25h | 2004-02-02 10:30 | 2004-02-02 10:45 | 91 | 251.97d | 0d |
| 93 | 2.2.4.5 | Define Item tracking codes | 0.25h | 2004-02-02 10:45 | 2004-02-02 11:00 | 92 | 251.97d | 0d |
| 94 | 2.2.4.6 | Define Locations | 0.25h | 2004-02-02 11:00 | 2004-02-02 11:15 | 93 | 251.97d | 0d |
| 95 | 2.2.4.7 | Define Items disc. Groups | 1h | 2004-02-02 11:15 | 2004-02-02 13:15 | 94 | 251.97d | 0d |
| 96 | 2.2.4.8 | Set-up and Implementation of parameters | 0.25h | 2004-02-02 13:15 | 2004-02-02 13:30 | 95 | 251.97d | 0d |
| 97 | 2.2.4.9 | Import Master Data | 0.5h | 2004-02-02 13:30 | 2004-02-02 14:00 | 96 | 251.97d | 0d |
| 98 | 2.2.4.11 | Verify imported master data | 2h | 2004-02-02 14:00 | 2004-02-02 16:00 | 97 | 251.97d | 0d |
| 99 | 2.2.4.12 | Item translations | 0.25h | 2004-02-02 16:00 | 2004-02-02 16:15 | 98 | 251.97d | 0d |
| 100 | 2.2.4.13 | Open Issues | 2.5h | 2004-02-02 16:15 | 2004-02-03 09:45 | 99 | 251.97d |  |
| 101 | 2.2.5 | **Day 5 - Sales & Purchase** | 0.88d | 2004-02-03 09:45 | 2004-02-04 08:45 | 88 | 251.97d |  |
| 102 | 2.2.5.1 | **Sales procedures** | 0.5d | 2004-02-03 09:45 | 2004-02-03 14:45 |  | 251.97d | 0d |
| 103 | 5.1.2.5.1.1 | Process Training - Sales | 0.5h | 2004-02-03 09:45 | 2004-02-03 10:15 |  | 252.66d |  |
| 104 | 2.2.5.1.1 | Going through the fields in a Sales order | 0.5h | 2004-02-03 09:45 | 2004-02-03 10:15 |  | 251.97d | 0d |
| 105 | 2.2.5.1.2 | Create test Sales orders – print order | 0.5h | 2004-02-03 10:15 | 2004-02-03 10:45 | 104 | 251.97d | 0d |
| 106 | 2.2.5.1.3 | Ship – print Shipment | 0.25h | 2004-02-03 10:45 | 2004-02-03 11:00 | 105 | 251.97d | 0d |
| 107 | 2.2.5.1.4 | Invoice – print invoice | 0.25h | 2004-02-03 11:00 | 2004-02-03 11:15 | 106 | 251.97d | 0d |
| 108 | 2.2.5.1.5 | Credit memo | 0.25h | 2004-02-03 11:15 | 2004-02-03 11:30 | 107 | 251.97d | 0d |
| 109 | 2.2.5.1.6 | Batch post Sales orders | 0.25h | 2004-02-03 11:30 | 2004-02-03 11:45 | 108 | 251.97d | 0d |
| 110 | 2.2.5.1.7 | Quote | 0.25h | 2004-02-03 11:45 | 2004-02-03 12:00 | 109 | 251.97d | 0d |
| 111 | 2.2.5.1.8 | Blanket Orders | 0.25h | 2004-02-03 13:00 | 2004-02-03 13:15 | 110 | 251.97d | 0d |
| 112 | 2.2.5.1.9 | Reminders | 1h | 2004-02-03 13:15 | 2004-02-03 14:15 | 111 | 251.97d | 0d |
| 113 | 2.2.5.1.10 | Delete all transactions | 0.25h | 2004-02-03 14:15 | 2004-02-03 14:30 | 112 | 251.97d | 0d |
| 114 | 2.2.5.1.11 | Reset number series | 0.25h | 2004-02-03 14:30 | 2004-02-03 14:45 | 113 | 251.97d | 0d |

Notes:
- 89: Training as defined in day 1
- 90: Precondition: / Customer Resource has competence in inventory and related areas. / Action: / - Discuss needs and consequences of Manufacturer codes / Post condition:/ A written decision of Manufacturer codes / Tasks for Customer resource: / - Create all needed Manufacturer codes
- 91: Precondition: / Customer Resource has competence in inventory and related areas. / Action: / - Discuss needs and consequences of Item category codes / Post condition:/ A written decision of Item category codes / Tasks for Customer resource: / - Create all needed Item category codes
- 92: Precondition: / Customer Resource has competence in inventory and related areas. / Action: / - Discuss needs and consequences of Product groups / Post condition:/ A written decision of Product groups / Tasks for Customer resource: / - Create all needed Product groups
- 93: Precondition: / Customer Resource has competence in inventory and related areas. / Action: / - Discuss needs and consequences of Item tracking codes / Post condition:/ A written decision of Item tracking codes / Tasks for Customer resource: / - Create all needed Item tracking codes
- 94: Precondition: / Customer Resource has competence in inventory and related areas. / Action: / - Discuss needs and consequences of Locations / Post condition:/ A written decision of Locations / Tasks for Customer resource: / Create all needed Locations
- 95: Precondition: / Customer Resource has competence in inventory, sales and discount policy of the company. / Action: / - Discuss needs and consequences of Items disc. Groups / Post condition:/ A written decision of Items disc. Groups / Tasks for Customer resource: / - Create all needed Items disc. Groups
- 96: Precondition: / Inventory Questionnaire filled out by customer, hence all inventory setup data are created in Excel / Action: / Open the implementation tool, choose Quest. data. Enter the path and filename that contains the questionnaire. Choose Import. / Post condition:/ Inventory setup data are imported to the Navision Database. / Tasks for Customer resource: / Validate that Imported data are correct.
- 97: Precondition: / Master Data Excel Spread sheet is filled out by customer. / Action: / Open the Migration Overview and import the Spreadsheet. / Solve errors shown in the Migration Matrix. / Select Master Data Template. / Apply error free data / Tip: Group Master Data according to Master Data Templates and import template by template. / This will drastically reduce the amount of data to be imported from spreadsheets. / Post condition:/ Items are imported to the Navision Database. / Tasks for Customer resource: / Validate that Imported data are correct
- 98: Precondition: / Master Data Excel Spread sheet is imported into Navision database. / Validation completed. / Action: / Verify imported data are correct by reviewing item cards. / Post condition:/ Imported data are verified. / Tasks for Customer resource: / Verify imported data
- 99: Precondition: / Master Data Excel Spread sheet is imported into Navision database. / Validation completed. / Action: / Create item translations. / Post condition:/ Item descriptions translated to all relevant languages. / Tasks for Customer resource: / Translate item descriptions.
- 100: Precondition: / Any not yet solved Issues / Action: / Post condition: / Tasks for Customer resource:
- 103: Training as defined in day 1
- 104: Precondition: / The customer has been on an Navision Introduction course. / The customer has been on an Navision Sales course. / Periodic Activities regarding Reminders are handled / Action: / Go through all the fields in every tab in Sales header form. / Go through every shown fields in Sales line form. / Post condition: / Tasks for Customer resource:
- 105: Precondition: / Day 1, 2, 3 and 4 are finished and all the basic data are filled in. / Action: / - Create a Sales order with minimum 2 item lines for a national customer / - Create a Sales order with minimum 2 item lines for a customer in the EU / - Create a Sales order with minimum 2 item lines for a foreign customer outside the EU / - Check Item availability / - Check prices, discounts, payment terms, delivery terms, VAT, weight, volume, collie, dimensions / - Make lines in the 3 orders with G/L Accounts / - Make lines in the 3 orders with text only / - Print out the orders / Post condition: / Tasks for Customer resource: / - Find relevant examples of former sales orders / - Check prices, discounts, payment terms, delivery terms, VAT, weight, volume, collie, Dimensions / - Check printed orders / Tasks for Customer resource:
- 106: Precondition: / The above 3 created sales orders / Action: / For every sales order: / Ship 1 item line totally / Ship 1 item line partly / Posting Test report / Posting F11 / Post condition:/ Check the posted Shipments / Print Shipments / Navigate Check the posted entries / Tasks for Customer resource:
- 107: Precondition: / The 3 Sales orders / Action: / For every Sales order: / Invoice 1 item line totally / Invoice 1 item line partly / Posting Test report / Posting F11 / Post orders completely / Post condition: / Check the posted invoices / Print invoices / Navigate Check the posted entries / Tasks for Customer resource:
- 108: Precondition: / Action: / Create Sales credit memo / Posting Test report / Posting F11 / Post condition: / Check the posted credit memo / Print credit memo / Navigate Check the posted entries / Tasks for Customer resource:
- 109: Precondition: / Action: / Create 2 - 4 Sales orders / Posting, Post batch, Fill in the Sales order numbers in the request form of the report / Run the report, explain the Options on the report tab / Explain how to deal with ex. "3 out of 4 were posted" / Post condition: / Tasks for Customer resource:
- 110: Precondition: / Action: / Create Sales quote / Make order / Post condition: / Tasks for Customer resource:
- 111: Precondition: / Action: / Create Sales blanket order / Make order / Post condition: / Tasks for Customer resource:
- 112: Precondition: / The customer is using reminders. / Action: / Set Working day back in time/ Create Sales orders / Ship & Invoice Sales orders / Set Working day to to-day. / Create reminders / Print - test report / Issue reminder / Print reminder / Post condition: / Tasks for Customer resource:
- 113: Precondition: / Action: / Implementation tool, Data cleaning tab, Push button "Clean" / Post condition: / Tasks for Customer resource:
- 114: Precondition: / Action: / All number series should be reset. Maybe number series should start at a higher number / Post condition: / Tasks for Customer resource:

| ID | WBS | Task | Type | Duration | Start | Finish | Predecessors | Total slack | Free slack |
| --- | --- | --- | --- | --- | --- | --- | --- | --- | --- |
| 115 | 2.2.5.2 | **Purchase Procedures** |  | 0.38d | 2004-02-03 14:45 | 2004-02-04 08:45 | 114 | 251.97d |  |
| 116 | 5.1.2.5.2.1 | Process Training - Purchase |  | 0.5h | 2004-02-03 14:45 | 2004-02-03 15:15 |  | 252.28d |  |
| 117 | 2.2.5.2.1 | Going through the fields in a Purchase order |  | 0.5h | 2004-02-03 14:45 | 2004-02-03 15:15 |  | 251.97d | 0d |
| 118 | 2.2.5.2.2 | Create test purchase orders – print order |  | 0.25h | 2004-02-03 15:15 | 2004-02-03 15:30 | 117 | 251.97d | 0d |
| 119 | 2.2.5.2.3 | Receive – print receipt |  | 0.25h | 2004-02-03 15:30 | 2004-02-03 15:45 | 118 | 251.97d | 0d |
| 120 | 2.2.5.2.4 | Invoice – print invoice |  | 0.25h | 2004-02-03 15:45 | 2004-02-03 16:00 | 119 | 251.97d | 0d |
| 121 | 2.2.5.2.5 | Credit memo |  | 0.25h | 2004-02-03 16:00 | 2004-02-03 16:15 | 120 | 251.97d | 0d |
| 122 | 2.2.5.2.6 | Batch post purchase orders |  | 0.25h | 2004-02-03 16:15 | 2004-02-03 16:30 | 121 | 251.97d | 0d |
| 123 | 2.2.5.2.7 | Quote |  | 0.25h | 2004-02-03 16:30 | 2004-02-03 16:45 | 122 | 251.97d | 0d |
| 124 | 2.2.5.2.8 | Blanket order |  | 0.5h | 2004-02-03 16:45 | 2004-02-04 08:15 | 123 | 251.97d | 0d |
| 125 | 2.2.5.2.9 | Delete all transactions |  | 0.25h | 2004-02-04 08:15 | 2004-02-04 08:30 | 124 | 251.97d | 0d |
| 126 | 2.2.5.2.10 | Reset number series |  | 0.25h | 2004-02-04 08:30 | 2004-02-04 08:45 | 125 | 251.97d |  |
| 127 | 2.2.5.3 | Open balances for Customers, Vendors, Inventory and G/L |  | 1h | 2004-02-03 14:45 | 2004-02-03 15:45 | 102 | 252.22d |  |
| 128 | 5.2 | **Training & Print Outs** |  | 0d | 2004-01-13 08:30 | 2004-01-13 08:30 |  | 268d |  |
| 129 | 5.2.1 | Training of End-Users | milestone | 0h | 2004-01-13 08:30 | 2004-01-13 08:30 |  | 268d |  |
| 130 | 5.2.2 | Reports & Documents | milestone | 0h | 2004-01-13 08:30 | 2004-01-13 08:30 |  | 268d |  |
| 131 | 5.2.3 | Training End-Users - Manufacturing | milestone | 0h | 2004-01-13 08:30 | 2004-01-13 08:30 |  | 268d |  |
| 132 | 5.2.4 | Training End-Users - Warehouse | milestone | 0h | 2004-01-13 08:30 | 2004-01-13 08:30 |  | 268d |  |
| 133 | 5.3 | **Extensions** |  | 1.12d | 2004-01-13 08:30 | 2004-01-14 09:30 |  | 266.88d |  |
| 134 | 5.3.1 | **1 Day Fixed Assets** |  | 1.12d | 2004-01-13 08:30 | 2004-01-14 09:30 |  | 266.88d |  |
| 135 | 5.3.1.1 | Process -Training "Fixed Assets" | milestone | 0h | 2004-01-13 08:30 | 2004-01-13 08:30 |  | 266.88d | 0d |
| 136 | 5.3.1.2 | Sign Off on the F/A Questionnaire |  | 1h | 2004-01-13 08:30 | 2004-01-13 09:30 | 135 | 266.88d | 0d |
| 137 | 5.3.1.3 | Validate Master Data Template |  | 1h | 2004-01-13 09:30 | 2004-01-13 10:30 | 136 | 266.88d | 0d |
| 138 | 5.3.1.4 | Decide Posting F/A Posting Groups |  | 1h | 2004-01-13 10:30 | 2004-01-13 11:30 | 137 | 266.88d | 0d |
| 139 | 5.3.1.5 | Decide F/A Classifications |  | 1h | 2004-01-13 11:30 | 2004-01-13 13:30 | 138 | 266.88d | 0d |
| 140 | 5.3.1.6 | Set up Depreciation Book and tables |  | 1h | 2004-01-13 13:30 | 2004-01-13 14:30 | 139 | 266.88d | 0d |
| 141 | 5.3.1.7 | Set up F/A Journals |  | 1h | 2004-01-13 14:30 | 2004-01-13 15:30 | 140 | 266.88d | 0d |
| 142 | 5.3.1.8 | Import of Fixed Assets |  | 1h | 2004-01-13 15:30 | 2004-01-13 16:30 | 141 | 266.88d | 0d |
| 143 | 5.3.1.9 | Decide on insurance type and Journals |  | 1h | 2004-01-13 16:30 | 2004-01-14 08:30 | 142 | 266.88d | 0d |
| 144 | 5.3.1.10 | Decide on maintenance |  | 1h | 2004-01-14 08:30 | 2004-01-14 09:30 | 143 | 266.88d |  |

Notes:
- 116: Training as defined in day 1
- 117: Precondition: / Action: / Create a new Purchase order. / Go through all the fields in every tab in purchase header form. / Go through every shown fields in purchase line form. / Post condition: / Tasks for Customer resource:
- 118: Precondition: / Day 1, 2, 3 and 4 are finished and all the basic data are filled in. / Action: / - Create a purchase order with minimum 2 item lines for a national vendor / - Create a purchase order with minimum 2 item lines for a vendor in the EU / - Create a purchase order with minimum 2 item lines for a foreign vendor outside the EU / - Check prices, discounts, payment terms, delivery terms, VAT, weight, volume, collie / - Make lines in the 3 orders with G/L Accounts / - Make lines in the 3 orders with text only / - Print out the orders / Post condition: / Tasks for Customer resource: / - Find relevant examples of former purchase orders / - Check prices, discounts, payment terms, delivery terms, VAT, weight, volume, collie / - Check printed orders
- 119: Precondition: / The above 3 created purchase orders / Action: / For every purchase order: / Receive 1 item line totally / Receive 1 item line partly / Posting Test report / Posting F11 / Post condition: / Check the posted receipts / Print receipts / Navigate Check the posted entries / Tasks for Customer resource:
- 120: Precondition: / The 3 purchase orders / Action: / For every purchase order: / Invoice 1 item line totally / Invoice 1 item line partly / Posting Test report / Posting F11 / Post orders completely / Post condition: / Check the posted invoices / Print invoices / Navigate Check the posted entries / Tasks for Customer resource:
- 121: Precondition: / Action: / Create purchase credit memo / Posting Test report / Posting F11 / Post condition: / Check the posted credit memo / Print credit memo / Navigate Check the posted entries / Tasks for Customer resource:
- 122: Precondition: / Action: / Create 2 - 4 purchase orders / Posting, Post batch, Fill in the purchase order numbers in the request form of the report / Run the report / Explain how to deal with ex. "3 out of 4 were posted" / Post condition: / Tasks for Customer resource:
- 123: Precondition: / Customer Resource has competence in purchase. / Action: / Create purchase quote / Make order / Post condition: / Tasks for Customer resource:
- 124: Precondition: / Action: / Create purchase blanket order / Make order / Post condition: / Tasks for Customer resource:
- 125: Precondition: / Action: / Implementation tool, Data cleaning tab, Push button "Clean" / Post condition: / Tasks for Customer resource:
- 126: Precondition: / Action: / All number series should be reset. Maybe number series should start at a higher number / Post condition: / Tasks for Customer resource:
- 127: Precondition: / The client have list with the balances and inventory / Action: / Create Sales Journal / Create purchase journal / Create Phys. inventory journal / Create G/L journal / Test and check the journals / Post the journals / Post condition: / Check the posted entries / Run reports showing the balances and inventory / Post condition: / Tasks for Customer resource:
- 129: Training as defined in day 1
- 130: Precondition: / Customer resources (Sales, Purchase, GL, Inventory) are participating. / Standard Reports introduces in day 1 / Standard Reports are not sufficient. / Action: / Create list of needed customer specific reports & Documents. / Create Functional Specification Requirement for each report on the list / Offer price and delivery for Customer Specific reports / NOTICE! Changes to reports are not included in the 2+5+2 project timeframe. / Post condition:/ Customer Specific reports are created, delivered, tested and approved by customer. / Tasks for Customer resource:
- 131: Training as defined in day 1
- 132: Training as defined in day 1
- 135: Training as defined in day 1
- 136: Precondition: / Implementation Questionnaire for FA Setup created from Navision available / Action: / Make a walkthrough of the questionnaire(s). / Sign off on the questionnaire. / Save questionnaire to disk. / Post condition: / Questionnaire is ready for import. / Tasks for Customer resource:
- 137: Precondition: / Customer resources (Finance) are participating. / Action: / Explain the functionality of the Master Data Templates. / Decide for possible Master Data Templates / - create necessary additional Master Data Templates / Post condition:/ Necessary Master Data Templates for FA are created. / Tasks for Customer resource: / Instruct users in using Master Data Templates together with Master Data Migration.
- 138: Precondition: / Client Resource has competence in G/L / F/A / Action: / - Refresh knowledge of consequence of Posting Groups. / - Discuss company Posting needs. / - According to the Chart of Account layout enter the posting groups needed. / - Create the posting setup necessary. / Post condition:/ A client-written decision of posting groups at Company / Tasks for Customer resource: / - Create all needed posting groups / - Create the posting setup
- 139: Precondition: / Customer Resource has competence in inventory and related areas. / Action: / - Discuss needs and consequences of F/A Classifications / Post condition:/ A written decision of F/A Classifications / Tasks for Customer resource: / Create all needed F/A Classifications
- 140: Precondition: / Customer Resource has competence in inventory and related areas. / Action: / - Discuss needs and consequences of Depreciation Book and tables / Post condition:/ A written decision of Depreciation Book and tables / Tasks for Customer resource: / Create all needed Depreciation Book and tables
- 141: Precondition: / Customer Resource has competence in inventory and related areas. / Action: / - Discuss needs and consequences of F/A Journals / Post condition:/ A written decision of F/A Journals / Tasks for Customer resource: / Create all needed F/A Journals
- 142: Precondition: / Master Data Excel Spread sheet is filled out by customer. / Action: / Open the Migration Overview and import the Spreadsheet. / Solve errors shown in the Migration Matrix. / Select Master Data Template. / Apply error free data / Tip: Group Master Data according to Master Data Templates and import template by template. / This will drastically reduce the amount of data to be imported from spreadsheets. / Post condition:/ Items are imported to the Navision Database. / Tasks for Customer resource: / Validate that Imported data are correct
- 143: Precondition: / Customer Resource has competence in inventory and related areas. / Action: / - Discuss needs and consequences of insurance type and Journals / Post condition:/ A written decision of insurance type and Journals / Tasks for Customer resource: / Create all needed insurance type and Journals
- 144: Precondition: / Customer Resource has competence in inventory and related areas. / Action: / - Discuss needs and consequences of maintenance / Post condition:/ A written decision of maintenance / Tasks for Customer resource: / Create all needed maintenance

| ID | WBS | Task | Type | Duration | Start | Finish | Predecessors | Total slack | Free slack |
| --- | --- | --- | --- | --- | --- | --- | --- | --- | --- |
| 145 | 5.3.2 | **1 Day Relationship Management** |  | 0.75d | 2004-01-13 08:30 | 2004-01-13 15:30 |  | 267.25d |  |
| 146 | 5.3.2.1 | Process Training "Marketing" | milestone | 0h | 2004-01-13 08:30 | 2004-01-13 08:30 |  | 267.25d | 0d |
| 147 | 5.3.2.2 | Sign Off on the Relationship Management Setup Questionnaire |  | 1h | 2004-01-13 08:30 | 2004-01-13 09:30 | 146 | 267.25d | 0d |
| 148 | 5.3.2.3 | Validate Master Data Templates |  | 1h | 2004-01-13 09:30 | 2004-01-13 10:30 | 147 | 267.25d | 0d |
| 149 | 5.3.2.4 | Decide on Mailing Groups |  | 1h | 2004-01-13 10:30 | 2004-01-13 11:30 | 148 | 267.25d | 0d |
| 150 | 5.3.2.5 | Decide on Campaign Status |  | 1h | 2004-01-13 11:30 | 2004-01-13 13:30 | 149 | 267.25d | 0d |
| 151 | 5.3.2.6 | Decide on Profile Questionnaire |  | 1h | 2004-01-13 13:30 | 2004-01-13 14:30 | 150 | 267.25d | 0d |
| 152 | 5.3.2.7 | Import of Contacts |  | 1h | 2004-01-13 14:30 | 2004-01-13 15:30 | 151 | 267.25d |  |
| 153 | 1 | **Extensions for medium size project** |  | 21.28d? | 2004-01-13 08:30 | 2004-02-11 10:45 |  | 246.72d |  |
| 154 | 3.1 | **+ 5 Days Manufacturing** |  | 9.31d? | 2004-01-13 08:30 | 2004-01-26 11:00 |  | 246.72d | 0d |
| 155 | 3.1.1 | **Day 1 Manufacturing Preparation** |  | 1d? | 2004-01-13 08:30 | 2004-01-14 08:30 |  | 255.03d |  |
| 156 | 5.4.1.1.1 | Manufacturing Kick off Meeting |  | 8h? | 2004-01-13 08:30 | 2004-01-14 08:30 |  | 255.03d |  |
| 157 | 5.4.1.1.2 | Manufacturing Implementation considerations |  | 8h? | 2004-01-13 08:30 | 2004-01-14 08:30 |  | 255.03d |  |
| 158 | 5.4.1.1.3 | Manufacturing - Item / Demand |  | 8h? | 2004-01-13 08:30 | 2004-01-14 08:30 |  | 255.03d |  |
| 159 | 5.4.1.1.4 | Introducing the Customer to the Data Migration Concept |  | 8h? | 2004-01-13 08:30 | 2004-01-14 08:30 |  | 255.03d |  |
| 160 | 3.1.2 | **Day 2+3 - Manufacturing Setup** |  | 7.53d? | 2004-01-13 08:30 | 2004-01-22 13:45 |  | 246.72d |  |
| 161 | 5.4.1.2.1 | Sign off on Manufacturing Setup Questionnaire |  | 8h? | 2004-01-13 08:30 | 2004-01-14 08:30 |  | 255.03d |  |
| 162 | 5.4.1.2.2 | Manufacturing - Item Master Data |  | 8h? | 2004-01-13 08:30 | 2004-01-14 08:30 |  | 255.03d |  |
| 163 | 5.4.1.2.3 | Definition of Manufacturing Master Data |  | 8h? | 2004-01-13 08:30 | 2004-01-14 08:30 |  | 255.03d |  |
| 164 | 3.1.2.4 | Define BOM and Routing |  | 1h | 2004-01-13 08:30 | 2004-01-13 09:30 |  | 246.72d | 0d |
| 165 | 5.4.1.2.5 | Define Routing Links |  | 8h? | 2004-01-13 09:30 | 2004-01-14 09:30 | 164 | 246.72d | 0d |
| 166 | 5.4.1.2.6 | Define Process oriented master data |  | 8h? | 2004-01-14 09:30 | 2004-01-15 09:30 | 165 | 246.72d | 0d |
| 167 | 5.4.1.2.7 | Production Schedule |  | 8h? | 2004-01-15 09:30 | 2004-01-16 09:30 | 166 | 246.72d | 0d |
| 168 | 5.4.1.2.8 | Production Forecast Names |  | 8h? | 2004-01-16 09:30 | 2004-01-19 09:30 | 167 | 246.72d | 0d |
| 169 | 5.4.1.2.9 | Define Capacity units of Measure |  | 8h? | 2004-01-19 09:30 | 2004-01-20 09:30 | 168 | 246.72d | 0d |
| 170 | 5.4.1.2.10 | Define Work shifts |  | 8h? | 2004-01-20 09:30 | 2004-01-21 09:30 | 169 | 246.72d | 0d |

Notes:
- 146: Training as defined in day 1
- 147: Precondition: / Implementation Questionnaire for R/M created from Navision available / Action: / Make a walkthrough of the questionnaire's). / Sign off on the questionnaire. / Save questionnaire to disk. / Post condition: / Questionnaire is ready for import. / Tasks for Customer resource:
- 148: Precondition: / Customer resources (Sales) are participating. / Customer resource has competence in Sales, Relationship Management and related areas. / Action: / Explain the functionality of the Master Data Templates. / Validate existing Master Data Templates for Contacts / Decide for possible Master Data Templates / - create necessary additional Master Data Templates / Post condition:/ Necessary Master Data Templates for Contacts are created. / Tasks for Customer resource: / Instruct users in using Master Data Templates together with Master Data Migration.
- 149: Precondition: / Customer resources (Sales) are participating. / Customer resource has competence in Sales, Relationship Management and related areas. / Action: / Explain the functionality of Mailing groups / Validate existing Mailing groups / Decide for possible additional Mailing groups / - create necessary additional Mailing groups / Post condition:/ Necessary Mailing groups are created. / Tasks for Customer resource:
- 150: Precondition: / Customer resources (Sales) are participating. / Customer resource has competence in Sales, Relationship Management and related areas. / Action: / Explain the functionality of Campaign Status / Validate existing Campaign Status / Decide for possible additional Campaign Status / - create necessary additional Campaign Status / Post condition:/ Necessary Campaign Status are created. / Tasks for Customer resource:
- 151: Precondition: / Customer resources (Sales) are participating. / Customer resource has competence in Sales, Relationship Management and related areas. / Action: / Explain the functionality of Profile Questionnaire / Validate existing Profile Questionnaire / Decide for possible additional Profile Questionnaire / - create necessary additional Profile Questionnaire / Post condition:/ Customer Resource is able to create Profile Questionnaire are created. / Tasks for Customer resource: / create additional Profile Questionnaires.
- 152: Precondition: / Customer resources (Sales) are participating. / Customer resource has competence in Sales, Relationship Management and related areas. / Master Data Excel Spread sheet is filled out by customer. / Action: / Open the Migration Overview and import the Spreadsheet. / Solve errors shown in the Migration Matrix. / Select Master Data Template. / Apply error free data / Tip: Group Master Data according to Master Data Templates and import template by template. / This will drastically reduce the amount of data to be imported from spreadsheets. / Post condition:/ Items are imported to the Navision Database. / Tasks for Customer resource: / Validate that Imported data are correct
- 156: Precondition: / Customer resources attend meeting / Action: / Consultant / Project manager performs kick-off meeting containing: / - Purpose of project / - Expectations for the Result / - Expectations for workload for each employee / - "Basic rules" for project * / Post condition:/ Customer resource is aware and ready for the project and know how to cooperate with consultant. / Task for Customer Manager / That all employees are motivated to do the project. / * Basic rules could be: / - Working Hours (start/end/lunch) / - Expected preparation / - Billing rules (Hours/Transportation/Hotels) (Especially for fixed price projects) / - Handling of project deviations / - Who is decision maker on Billable hours outside Project Scope? / - etc.
- 157: Precondition: / Customer Manufacturing Manager is participating. / Documentation for current workflow present. / Requirements for critical procedures. / Action: / Analysis of customer current workflow, with the purpose of setting up Navision Manufacturing accordingly. / Post condition:/ Analysis report, describing set up of Navision Manufacturing. / Tasks for Customer resource: / Create / enter setup data.
- 158: Items: / Manufacturing specific setup on Item card / Planning of Demand / Using Order Planning / ·Level-by-level principle / ·Impact on Availability / ·Links between Demand and Supply
- 159: Precondition: / Spreadsheets are created in Topic 9 (2.nd. preparation day) / Common guidelines for filling in data in the spreadsheets:/ Post condition: / Tasks for Customer resource:
- 161: Precondition: / Manufacturing Set-up Questionnaire / Common guidelines for filling in data in the spreadsheets:/ Post condition: / Tasks for Customer resource:
- 162: Manufacturing specific: / Replenishment Tab / Produced Items / ·Manufacturing Policy / ·Routing No. / ·Production BOM No. / ·Flushing Method / ·Scrap % / ·Lot Size / Planning Tab / ·Reordering Policy / ·Reserve / ·Order Tracking Policy
- 163: Precondition: / Customer Resource has competence in manufacturing and related areas. / Action: / ·Discuss needs and consequences of Shop calendar / ·Discuss needs and consequences of Work Center Groups / ·Discuss needs and consequences of Work Centers / ·Discuss needs and consequences of Standard Tasks / Post condition:/ A written decision of action points / Tasks for Customer resource: / - Create agreed master data
- 164: Precondition: / Customer Resource has competence in manufacturing and related areas. / Action: / ·Discuss needs and consequences of Bill of materials and Routings / ·Define possible Routing Links / Post condition:/ A written decision of Bill of materials and Routings (included possible links) / Tasks for Customer resource: / - Create all needed Bill of materials and Routings
- 166: ndition: / Customer Resource has competence in manufacturing and related areas. / Action: / ·Discuss needs and define of Stop Coder / ·Discuss needs and define Scrap Codes / ·Discuss and identify Capacity Constrained Resources / · / Post condition:/ A written decision of action points / Tasks for Customer resource: / - Create agreed process oriented master data

| ID | WBS | Task | Duration | Start | Finish | Predecessors | Total slack | Free slack |
| --- | --- | --- | --- | --- | --- | --- | --- | --- |
| 171 | 5.4.1.2.11 | **Master Data** | 1.41d | 2004-01-21 09:30 | 2004-01-22 13:45 | 170 | 246.72d |  |
| 172 | 3.1.2.6 | Import Master Data | 1h | 2004-01-21 09:30 | 2004-01-21 10:30 |  | 246.72d | 0d |
| 173 | 3.1.2.7 | Validate the imported Master data | 1h | 2004-01-21 10:30 | 2004-01-21 11:30 | 172 | 246.72d | 0d |
| 174 | 3.1.2.11 | Import Master Data Production Forecast | 0.25h | 2004-01-21 11:30 | 2004-01-21 11:45 | 173 | 246.72d | 0d |
| 175 | 3.1.2.12 | Validate imported master data Production Forecast | 1h | 2004-01-21 11:45 | 2004-01-21 13:45 | 174 | 246.72d | 0d |
| 176 | 3.1.2.13 | Import Master Data BOM's | 0.25h | 2004-01-21 13:45 | 2004-01-21 14:00 | 175 | 246.72d | 0d |
| 177 | 3.1.2.14 | Validate imported master data BOM's | 2.5h | 2004-01-21 14:00 | 2004-01-21 16:30 | 176 | 246.72d | 0d |
| 178 | 3.1.2.15 | Import Master Data Capacity UOM, Work Shift, Stop, Scrap, Quality Measure | 0.25h | 2004-01-21 16:30 | 2004-01-21 16:45 | 177 | 246.72d | 0d |
| 179 | 3.1.2.16 | Validate imported master Capacity UOM, Work Shift, Stop, Scrap, Quality Measure | 1h | 2004-01-21 16:45 | 2004-01-22 08:45 | 178 | 246.72d | 0d |
| 180 | 3.1.2.17 | Import Master Data Machine/Work Center (Group's | 0.25h | 2004-01-22 08:45 | 2004-01-22 09:00 | 179 | 246.72d | 0d |
| 181 | 3.1.2.18 | Validate imported master data Machine/Work Center (Group's | 1h | 2004-01-22 09:00 | 2004-01-22 10:00 | 180 | 246.72d | 0d |
| 182 | 3.1.2.19 | Import Master Data Routings | 0.25h | 2004-01-22 10:00 | 2004-01-22 10:15 | 181 | 246.72d | 0d |
| 183 | 3.1.2.20 | Validate imported master data Routings | 2.5h | 2004-01-22 10:15 | 2004-01-22 13:45 | 182 | 246.72d | 0d |
| 184 | 2.2.5.1 | **Day 4+5 Manufacturing and planning procedures** | 1.78d | 2004-01-22 13:45 | 2004-01-26 11:00 |  | 246.72d |  |
| 185 | 2.2.5.1.1 | Going through the fields in a Production order | 2h | 2004-01-22 13:45 | 2004-01-22 15:45 | 183 | 246.72d | 0d |
| 186 | 2.2.5.1.2 | Create test Production orders – print order | 2h | 2004-01-22 15:45 | 2004-01-23 08:45 | 185 | 246.72d | 0d |
| 187 | 2.2.5.1.3 | Change Production Order Status | 0.5h | 2004-01-23 08:45 | 2004-01-23 09:15 | 186 | 246.72d | 0d |
| 188 | 2.2.5.1.5 | Post Output and Hours | 0.5h | 2004-01-23 09:15 | 2004-01-23 09:45 | 187 | 246.72d | 0d |
| 189 | 2.2.5.1.4 | Post Material Consumption | 0.5h | 2004-01-23 09:45 | 2004-01-23 10:15 | 188 | 246.72d | 0d |
| 190 | 2.2.5.1.7 | Finish Production order | 2h | 2004-01-23 10:15 | 2004-01-23 13:15 | 189 | 246.72d | 0d |
| 191 | 2.2.5.1.10 | Delete all transactions | 0.25h | 2004-01-23 13:15 | 2004-01-23 13:30 | 190 | 246.72d | 0d |
| 192 | 2.2.5.1.11 | Reset number series | 0.25h | 2004-01-23 13:30 | 2004-01-23 13:45 | 191 | 246.72d | 0d |
| 193 | 3.1.3.9 | Planning Worksheet - Regenerative Plan - MPS | 0.5h | 2004-01-23 13:45 | 2004-01-23 14:15 | 192 | 246.72d | 0d |
| 194 | 3.1.3.10 | Release Firm Planned PO | 0.5h | 2004-01-23 14:15 | 2004-01-23 14:45 | 193 | 246.72d | 0d |
| 195 | 3.1.3.11 | Planning Worksheet - Regenerative Plan - MRP | 0.5h | 2004-01-23 14:45 | 2004-01-23 15:15 | 194 | 246.72d | 0d |
| 196 | 3.1.3.12 | Release Firm Planned PO | 0.5h | 2004-01-23 15:15 | 2004-01-23 15:45 | 195 | 246.72d | 0d |
| 197 | 3.1.3.13 | Warehouse Pick | 0.5h | 2004-01-23 15:45 | 2004-01-23 16:15 | 196 | 246.72d | 0d |
| 198 | 3.1.3.14 | Consumption Journal | 0.5h | 2004-01-23 16:15 | 2004-01-23 16:45 | 197 | 246.72d | 0d |
| 199 | 3.1.3.15 | Output Journal | 0.5h | 2004-01-23 16:45 | 2004-01-26 08:15 | 198 | 246.72d | 0d |
| 200 | 3.1.3.16 | Internal Put-aways | 0.5h | 2004-01-26 08:15 | 2004-01-26 08:45 | 199 | 246.72d | 0d |
| 201 | 3.1.3.17 | Put away | 0.5h | 2004-01-26 08:45 | 2004-01-26 09:15 | 200 | 246.72d | 0d |
| 202 | 3.1.3.18 | Finish Released PO | 0.5h | 2004-01-26 09:15 | 2004-01-26 09:45 | 201 | 246.72d | 0d |
| 203 | 3.1.3.19 | Repeat steps for other orders | 1.25h | 2004-01-26 09:45 | 2004-01-26 11:00 | 202 | 246.72d |  |

Notes:
- 172: Precondition: / Master Data Excel Spread sheet is filled out by customer. / Action: / Open the Migration Overview and import the Spreadsheet. / Solve errors shown in the Migration Matrix. / Select Master Data Template. / Apply error free data / Hint: Group Master Data according to Master Data Templates and import template by template. / This will drastically reduce the amount of data to be imported from spreadsheets. / Tables to import: / ·Data to Production Forecast / ·BOM's / ·Capacity UOM / ·Work shifts, / ·Stop Codes / ·Scrap Codes/ ·Quality Measure Codes / Post condition:/ Items are imported to the Navision Database. / Tasks for Customer resource:
- 173: Precondition: / Master Data Excel Spread sheet is imported into Navision database. / Action: / Open the Migration Matrix and validate / ·Data to Production Forecast / ·BOM's / ·Capacity UOM / ·Work shifts, / ·Stop Codes / ·Scrap Codes / ·Quality Measure Codes / Post condition:/ Imported master data are validated. / Tasks for Customer resource: / Apply Data
- 185: Precondition: / The customer has been on an Navision Introduction course. / The customer has been on an Navision Sales course. / The customer has been on an Navision Manufacturing Foundation course / Periodic Activities regarding Reminders are handled / Action: / Go through all the fields in every tab in Production Header form / Go through every shown fields in Production Line form / Post condition: / Tasks for Customer resource:
- 186: Precondition: / Day 1, 2, 3, 4, 5 and 6 are finished and all the basic data are filled in. / Action: / - Check of the items, which are used in the sales procedure test, have a BOM and Routing. When not create a test BOM and test Routing. / - Post inventory for the items which are used in the BOM / - Create for the three Sales orders from Task Sales Procedure - Create test Sales order with Order planning firm planned orders / - Print out the orders / - Schedule the orders with Graphical Scheduling / Post condition: / Tasks for Customer resource: / - Find relevant examples of former Production orders / - Check prices, quantities / - Check printed orders
- 187: Precondition: / The above 3 created production orders / Action: / Change every production order status to released / Post condition: / Tasks for Customer resource:
- 188: Precondition: / The above 3 created production orders / Action: / For every production order: / Post 1 production order line output and hours complete / Post 1 production order line output and hours partly / Posting Test report / Posting F11 / Post condition: / Check the posted output / Navigate Check the posted output / Tasks for Customer resource:
- 189: Precondition: / The above 3 created production orders / Action: / For every production order: / Post 1 production order line material consumption complete / Post 1 production order line material consumption partly / Posting Test report / Posting F11 / Post condition: / Check the posted material consumption / Navigate Check the material consumption / Tasks for Customer resource:
- 190: Precondition: / The above 3 created production orders / Action: / Change every production order status to finished / Run the batch job Adjust Cost - Item Entries / Run the batch job Post Inventory Cost to G/L / Post condition: / Check the posted inventory cost and results / Navigate Check the posted inventory cost and results / Tasks for Customer resource:
- 191: Precondition: / Action: / Implementation tool, Data cleaning tab, Push button "Clean" / Post condition: / Tasks for Customer resource:
- 192: Precondition: / Action: / All number series should be reset. Maybe number series should start at a higher number / Post condition: / Tasks for Customer resource:

| ID | WBS | Task | Duration | Start | Finish | Predecessors | Total slack | Free slack |
| --- | --- | --- | --- | --- | --- | --- | --- | --- |
| 204 | 3.2 | **+ 5 Days WareHouse Management** | 11.97d? | 2004-01-26 11:00 | 2004-02-11 10:45 | 154 | 246.72d |  |
| 205 | 3.2.1 | **Day 1 Warehouse Management Preparation** | 1d? | 2004-01-26 11:00 | 2004-01-27 11:00 |  | 246.72d | 0d |
| 206 | 5.4.2.1.1 | Kick Off Meeting - Warehouse | 8h? | 2004-01-26 11:00 | 2004-01-27 11:00 |  | 246.72d |  |
| 207 | 5.4.2.1.2 | Warehouse Management Implementation Considerations | 4h | 2004-01-26 11:00 | 2004-01-26 16:00 |  | 247.22d |  |
| 208 | 5.4.2.1.3 | Warehouse Management Process Considerations | 4h | 2004-01-26 11:00 | 2004-01-26 16:00 |  | 247.22d |  |
| 209 | 3.2.2 | **Day 2 Warehouse Management Setup** | 1.69d | 2004-01-26 11:00 | 2004-01-28 08:30 |  | 247.72d |  |
| 210 | 2.2.4.8 | Sign off Warehouse Set-up Questionnaire | 1h | 2004-01-26 11:00 | 2004-01-26 12:00 |  | 258.56d |  |
| 211 | 3.2.2.1 | Create Warehouse employees | 0.5h | 2004-01-27 11:00 | 2004-01-27 11:30 | 205 | 246.72d | 0d |
| 212 | 5.4.2.2.3 | Create Bin Templates | 0.5h | 2004-01-27 11:30 | 2004-01-27 12:00 | 211 | 246.72d | 0d |
| 213 | 5.4.2.2.4 | Create Bin Types | 0.5h | 2004-01-27 13:00 | 2004-01-27 13:30 | 212 | 246.72d | 0d |
| 214 | 5.4.2.2.5 | Create Warehouse Classes | 0.5h | 2004-01-27 13:30 | 2004-01-27 14:00 | 213 | 246.72d | 0d |
| 215 | 3.2.2.2 | Create Bins with Bin Creation Worksheet | 0.5h | 2004-01-27 14:00 | 2004-01-27 14:30 | 214 | 246.72d | 0d |
| 216 | 3.2.2.3 | Create Bin Contents | 0.5h | 2004-01-27 14:30 | 2004-01-27 15:00 | 215 | 246.72d | 0d |
| 217 | 3.2.2.4 | Warehouse Setup - Default Bins | 0.5h | 2004-01-27 15:00 | 2004-01-27 15:30 | 216 | 246.72d | 0d |
| 218 | 3.2.2.5 | Create Special Equipment | 0.5h | 2004-01-27 15:30 | 2004-01-27 16:00 | 217 | 246.72d | 0d |
| 219 | 3.2.2.6 | Create Warehouse Journal templates | 0.5h | 2004-01-27 16:00 | 2004-01-27 16:30 | 218 | 246.72d | 0d |
| 220 | 3.2.2.7 | Create Whse. Worksheet Template | 0.5h | 2004-01-27 16:30 | 2004-01-27 17:00 | 219 | 246.72d | 0d |
| 221 | 3.2.2.8 | Create Put-Away Template | 0.5h | 2004-01-28 08:00 | 2004-01-28 08:30 | 220 | 246.72d | 0d |
| 222 | 5.4.2.3 | **Day 3 Integration issues** | 5d? | 2004-01-28 08:30 | 2004-02-04 08:30 | 221 | 246.72d |  |
| 223 | 5.4.2.3.1 | Cross-Docking | 8h? | 2004-01-28 08:30 | 2004-01-29 08:30 |  | 246.72d | 0d |
| 224 | 5.4.2.3.2 | Warehouse Internal Put-Aways - Manufacturing | 8h? | 2004-01-29 08:30 | 2004-01-30 08:30 | 223 | 246.72d | 0d |
| 225 | 5.4.2.3.3 | Warehouse Internal Pick - Manufacturing | 8h? | 2004-01-30 08:30 | 2004-02-02 08:30 | 224 | 246.72d | 0d |
| 226 | 5.4.2.3.4 | Warehouse Phys. Inventory | 8h? | 2004-02-02 08:30 | 2004-02-03 08:30 | 225 | 246.72d | 0d |
| 227 | 5.4.2.3.5 | Warehouse Inventory Adjustments to the Item Ledger | 8h? | 2004-02-03 08:30 | 2004-02-04 08:30 | 226 | 246.72d | 0d |

Notes:
- 206: Precondition: / Customer resources attend meeting / Action: / Consultant / Project manager performs kick-off meeting containing: / - Purpose of project / - Expectations for the Result / - Expectations for workload for each employee / - "Basic rules" for project * / Post condition:/ Customer resource is aware and ready for the project and know how to cooperate with consultant. / Task for Customer Manager / That all employees are motivated to do the project. / * Basic rules could be: / - Working Hours (start/end/lunch) / - Expected preparation / - Billing rules (Hours/Transportation/Hotels) (Especially for fixed price projects) / - Handling of project deviations / - Who is decision maker on Billable hours outside Project Scope? / - etc.
- 207: WMS Setup / Clarify: / Bin Types / A bin is the smallest container unit in the WMS Warehouse. It is possible to restrict the activities that are allowed for a bin, by assigning a bin type to it. / ·Receive / ·Put-away / ·Pick / ·Ship / ·Receive and Pick / ·Put-away and Pick / ·Receive and 'Ship / ·None / Warehouse Classes / Work with warehouse classes and default receiving/shipping bin? / Setting maximum quantities for Bins / Set a maximum quantity of a specific item to be stored in an individual bin
- 208: Based on customers business process go over the following issues: / Goods Handling Order-by Order / Goods Handling Multiple Orders / Cross Docking / Integration / ·Manufacturing / ·Inventory
- 210: Precondition: / Warehouse Questionnaire filled out by customer, hence all warehouse setup data are created in Excel / Action: / Open the implementation tool, choose Quest. data. Enter the path and filename that contains the questionnaire. Choose Import. / Post condition:/ Warehouse setup data are imported to the Navision Database. / Tasks for Customer resource: / Validate that Imported data are correct.

| ID | WBS | Task | Duration | Start | Finish | Predecessors | Total slack | Free slack |
| --- | --- | --- | --- | --- | --- | --- | --- | --- |
| 228 | 3.2.3 | **Day 4 + 5 Warehouse Management Procedures** | 5.28d? | 2004-02-04 08:30 | 2004-02-11 10:45 |  | 246.72d |  |
| 229 | 5.4.2.4.1 | **Inbound Flow** | 2d? | 2004-02-04 08:30 | 2004-02-06 08:30 | 227 | 246.72d |  |
| 230 | 5.4.2.4.1.1 | Warehouse Inbound Request | 8h? | 2004-02-04 08:30 | 2004-02-05 08:30 |  | 251d |  |
| 231 | 5.4.2.4.1.2 | Warehouse Receipt (3 pcs.) | 8h? | 2004-02-04 08:30 | 2004-02-05 08:30 |  | 250d | 0d |
| 232 | 5.4.2.4.1.3 | Receipt Posting | 8h? | 2004-02-05 08:30 | 2004-02-06 08:30 | 231 | 250d |  |
| 233 | 5.4.2.4.1.4 | Warehouse Put-away Worksheet | 8h? | 2004-02-04 08:30 | 2004-02-05 08:30 |  | 246.72d | 0d |
| 234 | 5.4.2.4.1.5 | Warehouse Put-away | 8h? | 2004-02-05 08:30 | 2004-02-06 08:30 | 233 | 246.72d | 0d |
| 235 | 5.4.2.4.2 | **Internal Movements** | 0.09d | 2004-02-06 08:30 | 2004-02-06 09:15 |  | 246.72d |  |
| 236 | 3.2.3.3 | Movement Worksheet | 0.5h | 2004-02-06 08:30 | 2004-02-06 09:00 | 234 | 246.72d | 0d |
| 237 | 3.2.3.4 | Warehouse Movement | 0.25h | 2004-02-06 09:00 | 2004-02-06 09:15 | 236 | 246.72d | 0d |
| 238 | 5.4.2.4.3 | **Outbound Flow** | 3.19d? | 2004-02-06 09:15 | 2004-02-11 10:45 |  | 246.72d |  |
| 239 | 5.4.2.4.3.1 | Warehouse Outbound Request | 8h? | 2004-02-06 09:15 | 2004-02-09 09:15 | 237 | 246.72d | 0d |
| 240 | 3.2.3.5 | Warehouse Shipment | 0.25h | 2004-02-09 09:15 | 2004-02-09 09:30 | 239 | 246.72d | 0d |
| 241 | 5.4.2.4.3.3 | Print Shipment Document | 8h? | 2004-02-09 09:30 | 2004-02-10 09:30 | 240 | 246.72d | 0d |
| 242 | 5.4.2.4.3.4 | Planning the Picking Process | 8h? | 2004-02-10 09:30 | 2004-02-11 09:30 | 241 | 246.72d | 0d |
| 243 | 3.2.3.6 | Warehouse Pick | 0.25h | 2004-02-11 09:30 | 2004-02-11 09:45 | 242 | 246.72d | 0d |
| 244 | 3.2.3.20 | Warehouse Pick Worksheet | 0.5h | 2004-02-11 09:45 | 2004-02-11 10:15 | 243 | 246.72d | 0d |
| 245 | 3.2.3.21 | Warehouse Pick | 0.25h | 2004-02-11 10:15 | 2004-02-11 10:30 | 244 | 246.72d | 0d |
| 246 | 3.2.3.22 | Warehouse Ship | 0.25h | 2004-02-11 10:30 | 2004-02-11 10:45 | 245 | 246.72d |  |
| 247 | 6 | **Operate -Phase** | 2d? | 2004-01-13 08:30 | 2004-01-15 08:30 |  | 266d |  |
| 248 | 6.1 | **2+5+2 Concept** | 1d? | 2004-01-13 08:30 | 2004-01-14 08:30 |  | 267d |  |
| 249 | 6.1.1 | **2 Days Post Mortem** | 1d? | 2004-01-13 08:30 | 2004-01-14 08:30 |  | 267d |  |
| 250 | 6.1.1.1 | Day 1 - Evaluation | 8h? | 2004-01-13 08:30 | 2004-01-14 08:30 |  | 267d |  |
| 251 | 6.1.1.2 | Day 2 - Follow Up | 8h? | 2004-01-13 08:30 | 2004-01-14 08:30 |  | 267d |  |

| ID | WBS | Task | Duration | Start | Finish | Total slack |
| --- | --- | --- | --- | --- | --- | --- |
| 252 | 6.2 | **Extension** | 2d? | 2004-01-13 08:30 | 2004-01-15 08:30 | 266d |
| 253 | 6.2.1 | **2 Days Extended Post Mortem** | 2d? | 2004-01-13 08:30 | 2004-01-15 08:30 | 266d |
| 254 | 6.2.1.1 | Day 1 - Extended -evaluation | 16h | 2004-01-13 08:30 | 2004-01-15 08:30 | 266d |
| 255 | 6.2.1.2 | Day 2 - Extended - Follow Up | 8h? | 2004-01-13 08:30 | 2004-01-14 08:30 | 267d |
